# Injector-Linac Commissioning

Schedule from MS Project, 2006-06-01 to 2008-05-09.
Stanford Linear Accelerator Center

## Calendars

- 7 days a week - 1: Mon-Sun 08:00-12:00, 13:00-17:00. Exceptions (off unless hours are given): 2006-06-03 to 2006-06-04, 2006-06-10 to 2006-06-11, 2006-06-17 to 2006-06-18, 2006-06-24 to 2006-06-25, 2006-07-01 to 2006-07-02, 2006-07-08 to 2006-07-09, 2006-07-15 to 2006-07-16, 2006-07-22 to 2006-07-23, 2006-07-29 to 2006-07-30, 2006-08-05 to 2006-08-06, 2006-08-12 to 2006-08-13, 2006-08-19 to 2006-08-20, 2006-08-26 to 2006-08-27, 2006-09-02 to 2006-09-03, 2006-09-09 to 2006-09-10, 2006-09-16 to 2006-09-17, 2006-09-23 to 2006-09-24, 2006-09-30, 2006-10-07 to 2006-10-08, 2006-10-14 to 2006-10-15, 2006-10-21 to 2006-10-22, 2006-10-28 to 2006-10-29, 2006-11-04 to 2006-11-05, 2006-11-11 to 2006-11-12, 2006-11-18 to 2006-11-19, 2006-11-23 to 2006-11-26, 2006-12-02 to 2006-12-03, 2006-12-09 to 2006-12-10, 2006-12-16 to 2006-12-17, 2006-12-20 to 2007-01-01, 2007-01-06 to 2007-01-07, 2007-01-13 to 2007-01-14, 2007-01-20 to 2007-01-21, 2007-01-27 to 2007-01-28, 2007-02-03 to 2007-02-04, 2007-02-10 to 2007-02-11, 2007-02-17 to 2007-02-18, 2007-02-24 to 2007-02-25.

## Resources

| Resource |
| --- |
| Linac |
| Injector |
| Drive Laser |

## Schedule

| ID | WBS | Task | Type | Duration | Start | Finish | Predecessors | Total slack | Free slack | Constraint |
| --- | --- | --- | --- | --- | --- | --- | --- | --- | --- | --- |
| 1 | 1 | Injector Commissioning | milestone | 0d | 2006-06-01 | 2006-06-01 |  | 947d |  |  |
| 2 | 2 | **RF Gun Preparation** |  | 71d | 2006-06-01 | 2006-09-07 |  | 876d |  |  |
| 3 | 6 | **RF cold test** |  | 20d | 2006-06-01 | 2006-06-28 |  | 927d | 0d |  |
| 4 | 6.3 | characterize and tune gun |  | 20d | 2006-06-01 | 2006-06-28 |  | 927d |  | start no earlier than 2006-06-01 |
| 5 | 7 | **cathodes preparation and characterization** |  | 11d | 2006-06-01 | 2006-06-15 | 3SS | 876d | 0d |  |
| 6 | 7.5 | dummy cathode ------> for final magnetic charact. |  | 2d | 2006-06-01 | 2006-06-02 |  | 876d | 0d |  |
| 7 | 7.6 | first cathode --- cold test |  | 4d | 2006-06-05 | 2006-06-08 | 6 | 876d | 0d |  |
| 8 | 7.7 | second cathode ----> for hot test |  | 5d | 2006-06-09 | 2006-06-15 | 7 | 876d | 20d |  |
| 9 | 8 | **Integrate Gun + Solenoid + Valve + Bucking coil** |  | 25d | 2006-06-16 | 2006-07-20 | 5 | 876d |  |  |
| 10 | 8.4 | Connect, align, fiducialize |  | 10d | 2006-06-16 | 2006-06-29 |  | 876d | 0d |  |
| 11 | 8.5 | Magnetic measurements ---------> Roger and John (test plan) |  | 10d | 2006-06-30 | 2006-07-13 | 10 | 876d | 0d |  |
| 12 | 8.6 | Retune assembled gun |  | 5d | 2006-07-14 | 2006-07-20 | 8, 11 | 876d | 0d |  |
| 13 | 9 | **RF gun hot test in Klys. Lab** |  | 25d | 2006-07-21 | 2006-08-24 | 12 | 876d | 0d |  |
| 14 | 9.5 | Install and bake |  | 10d | 2006-07-21 | 2006-08-03 |  | 876d | 0d |  |
| 15 | 9.6 | RF processing |  | 15d | 2006-08-04 | 2006-08-24 | 14 | 876d | 0d |  |
| 16 | 2.4.3 | Gun assembly ready for S20 install. | milestone | 0d | 2006-08-24 | 2006-08-24 | 15 | 876d |  |  |
| 17 | 10 | **(defunct tasks) Gun Preparation at Sector 20** |  | 10d | 2006-08-25 | 2006-09-07 | 13 | 876d |  |  |
| 18 | 2.5.1 | Gun installation |  | 10d | 2006-08-25 | 2006-09-07 |  | 876d |  |  |
| 19 | 2.5.2 | RF gun +solenoid Checkouts |  | 2d | 2006-08-25 | 2006-08-28 |  | 884d | 0d |  |
| 20 | 2.5.3 | (defunct task) Gun Installed - ready for laser & RF | milestone | 0d | 2006-08-28 | 2006-08-28 | 19 | 884d |  |  |
| 21 | 13 | **Pre-Beam Checkout Injector/Linac beamlines** |  | 62.25d | 2006-12-13 | 2007-03-16 |  | 514.23d | 0d |  |
| 22 | 12 | Injector vault ready for pre-beam checkout | milestone | 0d | 2006-12-13 | 2006-12-13 |  | 570.48d | 0d | start no earlier than 2006-12-13 |
| 23 | 13.8 | Check Gun & GTL Beam Line |  | 1d | 2006-12-13 | 2006-12-13 | 22 | 570.48d | 0d |  |
| 24 | 13.9 | Check Gun-Spectrometer Branch Line |  | 1d | 2006-12-14 | 2006-12-14 | 23 | 570.48d | 0d |  |
| 25 | 13.10 | Check Main Injector Beam Line |  | 3d | 2006-12-15 | 2006-12-19 | 24 | 570.48d | 0d |  |
| 26 | 3.5 | Check SA Spectrometer Beam Line |  | 1d | 2007-01-02 | 2007-01-02 | 25 | 570.48d |  |  |
| 27 | 11 | Linac vault ready for pre-beam checkout | milestone | 0d | 2006-12-13 | 2006-12-13 |  | 571.48d | 0d | start no earlier than 2006-12-13 |
| 28 | 3.7 | Check Main Linac Beam Line |  | 5d | 2006-12-13 | 2006-12-19 | 27 | 571.48d |  |  |
| 29 | 2.22 | Injector RF Processing Complete | milestone | 0d | 2007-02-26 | 2007-02-26 |  | 532.23d | 0d | start no earlier than 2007-02-26 |
| 30 | 3.9 | Measure Gallery radiation, no gun |  | 2h | 2007-02-26 | 2007-02-26 | 29 | 532.23d |  |  |
| 31 | 3.9 | Measure Gallery Radiation, gun on |  | 2h | 2007-03-16 | 2007-03-16 | 33 | 514.23d |  |  |
| 33 | 2.9.7.7 | Gun ready for laser beam | milestone | 0d | 2007-03-16 | 2007-03-16 |  | 514.23d | 0d | start no earlier than 2007-03-16 |

Notes:
- 4: - bead-drop measurement / - link to Superfish plots / GTF measurements / (John--> plots of GTF measurements (bead-drop and bead rotation ...) / - set-up and equipement: / at klystron department / network analyzer .... / temperature sensor / chiller / - measurements / frequency vs temperature / Reflection coeff. vs freq. (--> Q, beta) / bead-drop / bead rotation / vs tuner / ACTION: / ---------- / simulations (which code?) / room ??? availability of klystron lab. / instruments / scheduling / gun balance / procedure to tune using back-plate / calibration of the 4 probes / position probes / check ~-47dB (check number) / verify stability of probe with temperature
- 5: cathode chararcterization (atomic force microscop of surface ruioghness) / QE measurement / H-ion beam cleaninng with QE meas. / XPS (X-Ray Photon-electron Spectroscopy) meas. surface contamination / --> define viability of cathode (w.r.t minimum quality requirement ) / (Dave must work out procedures for cathode prep.)
- 11: after replacing cathode with dummy cathode
- 13: The purpose of the gun hot test is to verify gun operation at high power before it's installation at S20. This test will require the entire gun+solenoid assembly to have the operational thermal mass of the gun when installed. / The test objectives are: / 1. Vacuum bake the gun to achieve 10^-10 torr / 2. Demonstrate the thermal control necessary to keep the gun on rf resonance / 3. Condition the gun to 120MV/m at any repetition rate / 4. Measure the gun's thermal distribution at low- and high-rf power. / 5. Measure the cell balance at high power using the rf probes.
- 15: automatic log vs time of / vacuum (+RGA) / RF breakdowns (FW , Reflected , probes) / dark current / ------> control algorithm??? / at 4kW ?? / (120Hz, 130MV/m ) xxx kW? / set-up / requires solenoid , power supply / Faraday Cup / Measurements: / fields from probes / forward and reflected power / vacuum / dark current / temperature in the gun body / monitor klystron parameters
- 19: RF gun -solenoid region / RF checks / solenoid, magnet polarity / interlocks / MPS, PPS tests
- 20: VVS not ON until Jan. 4
- 21: Includes checkout of Injector and new components in LInac up to two quads downstream of TD11.
- 23: Use Pre-Beam Tunnel Checklist (Emma). About 30 minutes per component was estimated.
- 24: Use Pre-Beam Tunnel Checklist (Emma). About 30 minutes per component was estimated.
- 25: Use Pre-Beam Tunnel Checklist (Emma). About 30 minutes per component was estimated.
- 26: Use Pre-Beam Tunnel Checklist (Emma). About 30 minutes per component was estimated.
- 28: Use Pre-Beam Tunnel Checklist (Emma). About 30 minutes per component was estimated.
- 30: Measure radiation in linac gallery: near sled cavities, rf hut and laser room (before gun installation is ok)
- 31: Measure radiation in linac gallery: near sled cavities, rf hut and laser room with gun rf on, but no uv laser beam on cathode.

| ID | WBS | Task | Type | Duration | Start | Finish | Predecessors | Total slack | Free slack |
| --- | --- | --- | --- | --- | --- | --- | --- | --- | --- |
| 34 | 7 | **Injector beamline commissioning** |  | 153.12d | 2007-03-16 | 2007-08-16 | 21, 33 | 514.23d |  |
| 35 | 7.8 | **First-pass commissioning/beam to SAB** |  | 27.5d | 2007-03-16 | 2007-04-12 |  | 514.23d |  |
| 36 | 7.8.7 | **Set Laser/RF Timing** |  | 4d | 2007-03-16 | 2007-03-20 |  | 514.23d |  |
| 37 | 7.8.7.5 | Calibrate diode and rf cables |  | 2d | 2007-03-16 | 2007-03-18 |  | 744.75d |  |
| 38 | 7.8.7.6 | Measure time delay between diode and rf signals |  | 2d | 2007-03-16 | 2007-03-18 |  | 744.75d |  |
| 39 | 7.8.7.7 | Set crude laser/RF timing |  | 2d | 2007-03-16 | 2007-03-18 |  | 514.23d | 0d |
| 40 | 7.8.7.8 | Coarse Timing of all RF structures |  | 2d | 2007-03-18 | 2007-03-20 | 39 | 514.23d | 0d |
| 41 | 5.1.2 | **Transport beam through GTL to YAG02** |  | 4d | 2007-03-20 | 2007-03-24 |  | 514.23d |  |
| 42 | 6 | Find photo-beam on Yag01, Yag02 |  | 2d | 2007-03-20 | 2007-03-22 | 40 | 514.23d | 0d |
| 43 | 8 | Center laser on solenoid field |  | 1d | 2007-03-22 | 2007-03-23 | 42 | 514.23d | 0d |
| 44 | 9 | Check alignment of RF axis |  | 1d | 2007-03-23 | 2007-03-24 | 43 | 514.23d | 0d |
| 45 | 10 | Laser crude centering in gun completed; mark laser center on virtual cathode | milestone | 0d | 2007-03-24 | 2007-03-24 | 44 | 514.23d | 0d |
| 46 | 7.8.9 | **Transport beam into BXG dump** |  | 4d | 2007-03-24 | 2007-03-28 | 45 | 514.23d |  |
| 47 | 5.1.3.1 | measure energy on YAGG1 |  | 1d | 2007-03-24 | 2007-03-25 |  | 514.23d | 0d |
| 48 | 7.8.9.4 | calibration of Vrf, Phase |  | 1d | 2007-03-25 | 2007-03-26 | 47 | 514.23d | 0d |
| 49 | 7.8.9.3 | Checkout components |  | 1d | 2007-03-26 | 2007-03-27 | 48 | 514.23d | 0d |
| 50 | 5.1.3.4 | possible access for repairs |  | 1d | 2007-03-27 | 2007-03-28 | 49 | 514.23d | 0d |
| 51 | 7.8.10 | **Transport beam to BXS dump** |  | 9.5d | 2007-03-28 | 2007-04-06 | 50 | 514.23d |  |
| 52 | 5.1.2.2 | Measure Laser room Radiation |  | 6h | 2007-03-28 | 2007-03-28 | 50 | 514.23d | 0d |
| 53 | 5.1.4.2 | Measure Gallery Radiation |  | 6h | 2007-03-29 | 2007-03-29 | 52 | 514.23d | 0d |
| 54 | 7.8.10.5 | **beam to YAG03** |  | 1.25d | 2007-03-29 | 2007-03-30 |  | 514.23d |  |
| 55 | 7.8.10.5.3 | beam through L0a |  | 1d | 2007-03-29 | 2007-03-30 | 53 | 514.23d | 0d |
| 56 | 7.8.10.5.4 | sanity check of SC2,SC3 |  | 0.25d | 2007-03-30 | 2007-03-30 | 55 | 514.23d | 0d |
| 57 | 7.8.10.6 | **beam to YAG04** |  | 1.5d | 2007-03-31 | 2007-04-01 |  | 514.23d |  |
| 58 | 5.1.4.4.1 | beam through L0b |  | 1d | 2007-03-31 | 2007-03-31 | 56 | 514.23d | 0d |
| 59 | 7.8.10.6.3 | sanity check of QA01,QA02, SOL2, etc |  | 0.5d | 2007-04-01 | 2007-04-01 | 58 | 514.23d | 0d |

Notes:
- 34: Commissioning starts requires / PPS, MPS , => BAS / RF signal available
- 37: determine the relative lengths of the rf and diode cables
- 38: Measure the gun Probe RF amplitude signal and photodiode signal vs time
- 39: Add delay as necessary to trigger laser at desired time during rf signal
- 40: check with scope the 3 RF forms w.r.t laser pulse
- 41: wobble option for all knobs in CS
- 42: Set camera timing on YAG01,02 / adjust injector RF phase / steer using SC0 / align to laser fiducials
- 43: Move laser until beam centroid independent of solenoid field variation
- 44: vary phase and/or amplitude and check for beam motion on YAG01/02
- 49: -FCG1 vs. IM01 & FC01 / -QG01, 2, 3 / -BPMG1 / -steering
- 51: all quads and steerers are off to start / BXS on at nominal (135MeV) / wobble option
- 52: measure radiation in laser room and around pps barrier, with e- beam parked on fco1, yag02, yag03, yag04, fcg1, and check BSOIC readings. Sector
- 53: Measure radiation in gallery near penetrations 21-1, 21-2, with e- parked on 135 MeV spectrometer sdmp, and calibrate LION1A AND LION1B.
- 55: measure position YAG03 / (try to minimize steering effects and reasonable beam shape) / scan phase until beam size minimum at YAG03 / check signal at BPM5
- 58: NEED YAG04 !!!!!!!!!!!!!!!!!!!!!!!!!!!!!!!!!!!!!!!!!!!!!!!! / check beam present at BPM6, BPM7 , BPM8 , BPM9 , BPM10 until YAGS1 / scan phase until decent beam shape and steering little affected / measure current at IM02 / QA01 and QA02 are off

| ID | WBS | Task | Type | Duration | Start | Finish | Predecessors | Total slack | Free slack |
| --- | --- | --- | --- | --- | --- | --- | --- | --- | --- |
| 60 | 7.8.10.7 | **beam to YAGS1** |  | 2d | 2007-04-01 | 2007-04-03 | 59 | 514.23d |  |
| 61 | 7.8.10.7.4 | steer with SC6, SC7 SC8 |  | 0.5d | 2007-04-01 | 2007-04-01 |  | 514.23d | 0d |
| 62 | 7.8.10.7.5 | sanity check of QE01,QE02,QE03,QE04,QM01,QM02 |  | 0.5d | 2007-04-02 | 2007-04-02 | 61 | 514.23d | 0d |
| 63 | 7.8.10.7.6 | coarse tuning of matching section |  | 1d | 2007-04-02 | 2007-04-03 | 62 | 514.23d | 0d |
| 64 | 7.8.10.8 | **beam on YAGS2** |  | 3.25d | 2007-04-03 | 2007-04-06 | 63 | 514.23d |  |
| 65 | 7.8.10.8.7 | vary BXS to center e- on YAGS2 |  | 0.5d | 2007-04-03 | 2007-04-03 |  | 514.23d | 0d |
| 66 | 5.1.4.6.2 | Set energy to 135 MeV (BXS nom.) |  | 1d | 2007-04-04 | 2007-04-04 | 65 | 514.23d | 0d |
| 67 | 7.8.10.8.9 | compare IMS1 to IM01,2,3 |  | 0.25d | 2007-04-05 | 2007-04-05 | 66 | 514.23d | 0d |
| 68 | 7.8.10.8.10 | sanity check of quadrupoles QS01, QS02 |  | 0.25d | 2007-04-05 | 2007-04-05 | 67 | 514.23d | 0d |
| 69 | 7.8.10.8.11 | sanity check of steering coils SCS1, SCS2 |  | 0.25d | 2007-04-05 | 2007-04-05 | 68 | 514.23d | 0d |
| 70 | 7.8.10.8.12 | Beam to BXS Dump | milestone | 0d | 2007-04-05 | 2007-04-05 | 69 | 514.23d | 0d |
| 71 | 5.1.4.6.7 | possible access for repairs |  | 1d | 2007-04-05 | 2007-04-06 | 70 | 514.23d | 0d |
| 72 | 7.8.8 | **Time diagnostics** |  | 4d | 2007-04-06 | 2007-04-10 |  | 514.23d |  |
| 73 | 7.8.8.5 | Time BPMs |  | 1d | 2007-04-06 | 2007-04-07 | 71 | 514.23d | 0d |
| 74 | 7.8.8.7 | time IM01,IM02,IM03 |  | 0.5d | 2007-04-07 | 2007-04-08 | 73 | 514.23d | 0d |
| 75 | 5.1.5.3 | Checkout MPS SAB comparator |  | 0.5d | 2007-04-08 | 2007-04-08 | 74 | 514.23d | 0d |
| 76 | 7.8.8.8 | **timing of cameras (gate adjustement)** |  | 1d | 2007-04-08 | 2007-04-09 |  | 514.23d |  |
| 77 | 7.8.8.8.3 | YAGs |  | 0.5d | 2007-04-08 | 2007-04-09 | 75 | 514.23d | 0d |
| 78 | 7.8.8.8.4 | OTRs (OTR1, OTR2,OTR3) |  | 0.5d | 2007-04-09 | 2007-04-09 | 77 | 514.23d | 0d |
| 79 | 7.8.8.9 | timing of the WireScanners |  | 0.5d | 2007-04-09 | 2007-04-10 | 78 | 514.23d | 0d |
| 80 | 7.8.8.10 | timing of Phase Cavity |  | 0.5d | 2007-04-10 | 2007-04-10 | 79 | 514.23d | 0d |
| 81 | 7.8.11 | **Timing and linac gradient calibration** |  | 2d | 2007-04-10 | 2007-04-12 |  | 514.23d |  |
| 82 | 7.8.11.11 | **Adjust RF timing for the L0a,b RF systems** |  | 2d | 2007-04-10 | 2007-04-12 | 80 | 514.23d |  |
| 83 | 7.8.11.11.1 | Check calibration of phase shifters (360 degrees variation) |  | 1d | 2007-04-10 | 2007-04-11 |  | 514.23d | 0d |

Notes:
- 61: all quadrupoles in matching section are off at this point / use only steering coils SC6, SC7 , SC8 / SC6 sanity check at BPM8, BMP9 / SC7 sanity check at BPM10, BPM11 / SC8 sanity check at BPM12, BMPS1 / SC6 , z = 11.07 / SC7, z = 11.85 / SC8, z = 16.7 (just before QM02) / BPM8 , z = 11.57 / BPM9, z = 11.97 / BPM10, z = 14.43 / BPM11, z = 16.36 / BPM12, z = 16.9 / BPMS1, z = 18.76 / BPMS2 , z = 20.0 / BPMS3, z = 21.2
- 69: SCS1, z = 17.99 / SCS2, z = 20.34 / with BPMS2, BPMS3 / BPMS2, z = 20.0 / BPMS3, z = 21.2
- 74: set gate timing around photo-electron pulse / (for suppression of dark current)
- 82: check with scope signal from IM02 with the 3 RF wave forms / maximize energy at BPMS2, (and YAGS2) / 1- adjust phase of L0a, L0b / 2- shift delay of modulator trigger / Check calibration of phase shifter (360 degrees variation) / Check calibration of RF power level by measuring energy as a function of RF (amp.,phase) / find how the delay introduced by cable length is determined

| ID | WBS | Task | Type | Duration | Start | Finish | Predecessors | Total slack | Free slack |
| --- | --- | --- | --- | --- | --- | --- | --- | --- | --- |
| 84 | 7.8.11.11.2 | **Calibration of L0a,b RF gradients** |  | 1d | 2007-04-11 | 2007-04-12 | 83 | 514.23d |  |
| 85 | 7.8.11.11.2.1 | Calibration RF power <-> peak voltage |  | 1d | 2007-04-11 | 2007-04-12 |  | 514.23d | 0d |
| 86 | 5.2 | Rough steer with BPMs in full injector |  | 1d | 2007-04-12 | 2007-04-13 | 85 | 514.23d | 0d |
| 87 | 7.2 | Beam ready for transport to BC1 dump | milestone | 0d | 2007-04-13 | 2007-04-13 | 86 | 514.23d | 0d |
| 88 | 7.9 | **Second-pass commissioning/characterization** |  | 41.12d | 2007-05-12 | 2007-06-22 | 169 | 516.23d | 0d |
| 89 | 7.9.3 | **Gun and Solenoid characterization** |  | 18.62d | 2007-05-12 | 2007-05-30 |  | 516.23d |  |
| 90 | 5.4.1.1 | Calibration of IM01 with beam |  | 2d | 2007-05-12 | 2007-05-13 |  | 517.85d | 1.62d |
| 91 | 7.9.3.11 | Gun energy measurement |  | 3d | 2007-05-17 | 2007-05-20 | 98 | 516.23d | 0d |
| 92 | 7.9.3.21 | QE measurements |  | 1d | 2007-05-20 | 2007-05-21 | 91 | 516.23d | 0d |
| 93 | 7.9.3.12 | Schottky scan |  | 3d | 2007-05-21 | 2007-05-24 | 92 | 516.23d | 0d |
| 94 | 7.9.3.16 | Gun energy vs phase at 200pC |  | 3d | 2007-05-24 | 2007-05-27 | 93 | 516.23d | 0d |
| 95 | 7.9.3.25 | Measure bunch length at CR01 (low charge) vs injection phase |  | 3d | 2007-05-27 | 2007-05-30 | 94 | 516.23d | 0d |
| 96 | 7.9.7 | **Feedback and diagnostics commissioning** |  | 9d | 2007-05-15 | 2007-05-24 |  | 516.23d |  |
| 97 | 7.9.7.20 | Gun Voltage resonance control |  | 1d | 2007-05-15 | 2007-05-16 | 90 | 552.73d |  |
| 98 | 7.9.7.8 | Charge stabilization |  | 2d | 2007-05-15 | 2007-05-17 | 90 | 516.23d | 0d |
| 99 | 7.9.7.9 | Gun /Voltage / Phase feedback |  | 3d | 2007-05-15 | 2007-05-18 | 90 | 544.73d | 0d |
| 100 | 7.9.7.10 | Transverse orbit feedback in GTL |  | 4d | 2007-05-18 | 2007-05-22 | 99 | 544.73d | 0d |
| 101 | 7.9.7.7 | Commissioning Phase monitor |  | 2d | 2007-05-22 | 2007-05-24 | 100 | 544.73d |  |
| 102 | 7.9.4 | **135MeV beam characterization** |  | 22.5d | 2007-05-30 | 2007-06-22 |  | 516.23d |  |
| 103 | 7.9.4.8 | **First projected emittance measurement** |  | 5d | 2007-05-30 | 2007-06-04 |  | 516.23d | 0d |
| 104 | 7.9.4.8.3 | **Measurement with WS** |  | 3d | 2007-05-30 | 2007-06-02 |  | 516.23d |  |
| 105 | 7.9.4.8.3.6 | test WS |  | 1.5d | 2007-05-30 | 2007-06-01 | 95 | 516.23d | 0d |
| 106 | 7.9.4.8.3.7 | steering through quads |  | 0.25d | 2007-06-01 | 2007-06-01 | 105 | 516.23d | 0d |
| 107 | 7.9.4.8.3.8 | quad calibration |  | 0.25d | 2007-06-01 | 2007-06-01 | 106 | 516.23d | 0d |
| 108 | 7.9.4.8.3.9 | tune to model for 60 degrees phase advance |  | 0.5d | 2007-06-01 | 2007-06-02 | 107 | 516.23d | 0d |
| 109 | 7.9.4.8.3.10 | measurement with WS |  | 0.5d | 2007-06-02 | 2007-06-02 | 108 | 516.23d | 0d |

Notes:
- 84: Check calibration of RF power level by measuring energy as a function of RF (amp.,phase)
- 85: Absolute calibration of L0a gradient (vs power level) / ·switch off L0b / ·measure energy at spectrometer as a function of phase to maximize energy / and repeat at various power levels / (requires good calibration of BXS also at half current -> ~ 64 MeV) / Absolute calibration of L0b gradient (vs power level) / ·measure energy at spectrometer as a function of phase to maximize energy / Feed info. in appropriate database
- 90: Measure IM01 vs charge / Measure FC01 vs charge in parallel / Setup nominal beam at 200pC / Measure charge with FC01 & IM01 vs laser intensity / Analyze data for IM01 calibration and enter into data base
- 91: set bunch charge to 200pC and launch beam at 30degrees / set trajectory to Alignment Laser (AL) reference on YAG01/YAG02 / Insert YAG01 & adjust S1 to form waist at YAG01 / Remove YAG01 & remove wakefield plug / "Turn on gun spectrometer, BXG" / "Sweep BXG current until beam is centered on YAGG1, " / Measure beam centroid vs BXG current. Does result agree with BXG field measurements? / Measure charge with IM01 and FCG1: Do they agree? / Calibration of BPMG1 / "Measure beam sizes on YAG01 and YAGG1, Do results agree with model?" / Adjust BXG and SC1 to center beam on YAGG1 / Measure centroid and rms size : convert into energy and energy spread / Switch on QG02 and QG03 to values given by model / Measure centroid and rms size : convert into energy and energy spread
- 92: Charge vs laser energy / Verify QE linearity and no abnormalities / Measure photo-charge ( from 10-500 pC) on FC01
- 93: move gun phase shifter by 360 or 720 degrees / and check that same charge at FC01 / verify 120 degrees of emission , and nowhere else / Measure charge at FC01 vs RF gun phase / With laser off measure dark current on FCO1 to test FC01. / Turn laser on and vary rfphase to maximize measured photo-current emitted from the gun / Scan over 720 degrees to verify the Schottky scan is periodic with 360 degree period / Verify the current is emitted only over approximately 120 degrees / Test for satellite laser pulses and laser timing jitter / measure laser-RF temporal jitter / Compare Schottky data with model / measure laser-RF temporal jitter
- 94: set to gun to 100 MV/m ans insert FC01 / turn solenoid to pretend to collect all the charge / Set up beamline for energy spread measurement on spectrometer screen / Verify laser pulse length less than 2 ps FWHM / Measure beam size on spectrometer screen as a function of RF phase and amplitude
- 98: charge feedback based on IM01 reading

| ID | WBS | Task | Type | Duration | Start | Finish | Predecessors | Total slack | Free slack |
| --- | --- | --- | --- | --- | --- | --- | --- | --- | --- |
| 110 | 7.9.4.8.4 | **measurement with OTRs** |  | 2d | 2007-06-02 | 2007-06-04 |  | 516.23d |  |
| 111 | 7.9.4.8.4.4 | check calibration screens |  | 0.5d | 2007-06-02 | 2007-06-03 | 109 | 516.23d | 0d |
| 112 | 7.9.4.8.4.5 | emittance measurement |  | 0.5d | 2007-06-03 | 2007-06-03 | 111 | 516.23d | 0d |
| 113 | 7.9.4.8.4.6 | Emittance WS/ OTR for small S1 variations |  | 1d | 2007-06-03 | 2007-06-04 | 112 | 516.23d |  |
| 114 | 7.9.4.9 | **First Bunch length measurement with TCAV** |  | 3d | 2007-06-04 | 2007-06-07 |  | 516.23d |  |
| 115 | 7.9.4.9.4 | checkout TCAV |  | 2d | 2007-06-04 | 2007-06-06 | 103 | 516.23d | 0d |
| 116 | 7.9.4.9.5 | low charge with different RF phase |  | 1d | 2007-06-06 | 2007-06-07 | 115 | 516.23d | 0d |
| 117 | 7.9.4.11 | **First Longitudinal Phase Space measurement** |  | 3.5d | 2007-06-07 | 2007-06-11 | 116 | 516.23d |  |
| 118 | 7.9.4.11.7 | set up beam for TCAV |  | 0.5d | 2007-06-07 | 2007-06-08 | 116 | 516.23d | 0d |
| 119 | 7.9.4.11.9 | crude measurement at YAGS2 |  | 1d | 2007-06-08 | 2007-06-09 | 118 | 516.23d | 0d |
| 120 | 7.9.4.11.10 | uncorrelated energy spread at OTRS1 |  | 2d | 2007-06-09 | 2007-06-11 | 119 | 516.23d | 0d |
| 121 | 7.9.4.10 | **First Slice emittance (H) measurement** |  | 6d | 2007-06-11 | 2007-06-17 |  | 516.23d |  |
| 122 | 7.9.4.10.5 | set up beam for TCAV slice emittance |  | 3d | 2007-06-11 | 2007-06-14 | 120 | 516.23d | 0d |
| 123 | 7.9.4.10.8 | solenoid scan |  | 3d | 2007-06-14 | 2007-06-17 | 122 | 516.23d | 0d |
| 124 | 7.9.4.12 | **First slice emittance (V) measurement** |  | 5d | 2007-06-17 | 2007-06-22 |  | 516.23d |  |
| 125 | 7.9.4.12.3 | tune optics, L0b off crest |  | 4d | 2007-06-17 | 2007-06-21 | 123 | 516.23d | 0d |
| 126 | 7.9.4.12.4 | measure at OTRS1 |  | 1d | 2007-06-21 | 2007-06-22 | 125 | 516.23d | 0d |
| 127 | 5.5 | Injector beam characterized | milestone | 0d | 2007-06-22 | 2007-06-22 | 126 | 648.88d |  |
| 128 | 7.10 | **Third-pass commissioning/machine studies** |  | 15d | 2007-08-01 | 2007-08-16 | 209 | 516.23d | 0d |
| 129 | 7.10.3 | **third pass 6MeV beam characterization** |  | 5d | 2007-08-01 | 2007-08-06 |  | 525.23d |  |
| 130 | 7.10.3.13 | **Cathode characterization** |  | 3.5d | 2007-08-01 | 2007-08-04 |  | 527.73d |  |
| 131 | 7.10.3.13.13 | **Uniformity of emission** |  | 0.5d | 2007-08-01 | 2007-08-01 |  | 527.73d |  |
| 132 | 7.10.3.13.13.4 | Point-to-point imaging of cathode on YAG01 , find Vrf, Phase, Solenoid |  | 0.5d | 2007-08-01 | 2007-08-01 |  | 530.73d |  |
| 133 | 7.10.3.13.13.5 | Compare electron beam and laser beam profiles |  | 0.5d | 2007-08-01 | 2007-08-01 |  | 530.73d |  |
| 134 | 7.10.3.13.13.6 | Repeat at YAG02 |  | 0.5d | 2007-08-01 | 2007-08-01 |  | 527.73d | 0d |

Notes:
- 115: verify beam steering with phase / check for reference for the two zero-crossing / check amplitude calibration on OTR2 (or YAGS1 if not enough light)
- 121: tune optics / switch TCAV on / measure slice emittance at OTR2 or YAGS1
- 130: for 15pC cases, short pulse (~2ps) required
- 132: Try to image Air Force Target (assumes Air Force Target has been imaged on virtual cathode camera) / Compare values with theoretical model / try a different combination (Vrf,phase, Solenoid) wihch gives a different magnification
- 134: for both YAG01 and YAG02 imaging settings: / Verify round beam over solenoid around set-up values

| ID | WBS | Task | Type | Duration | Start | Finish | Predecessors | Total slack | Free slack |
| --- | --- | --- | --- | --- | --- | --- | --- | --- | --- |
| 135 | 7.10.3.13.4 | **Measure QE spatial profile** |  | 1d | 2007-08-01 | 2007-08-02 | 134 | 527.73d |  |
| 136 | 7.10.3.13.4.4 | Focus laser to approximately 100-200 microns spot size |  | 1d | 2007-08-01 | 2007-08-02 |  | 529.73d |  |
| 137 | 7.10.3.13.4.6 | Scan laser across 2.5 X 2.5 mm array and measure photo-charge on FC01 |  | 1d | 2007-08-01 | 2007-08-02 |  | 527.73d | 0d |
| 138 | 7.10.3.13.5 | **Thermal emittance** |  | 2d | 2007-08-02 | 2007-08-04 | 137 | 527.73d |  |
| 139 | 7.10.3.13.5.4 | Divergence to point imaging |  | 0.5d | 2007-08-02 | 2007-08-03 |  | 529.23d |  |
| 140 | 7.10.3.13.5.5 | Compare set point with theoretical model prediction |  | 0.5d | 2007-08-02 | 2007-08-03 |  | 529.23d |  |
| 141 | 7.10.3.13.5.6 | Repeat with another set of parameters (Vrf) giving a different magnification |  | 2d | 2007-08-02 | 2007-08-04 |  | 527.73d |  |
| 142 | 7.10.3.13.6 | **Momentum distribution** |  | 1d | 2007-08-01 | 2007-08-02 |  | 530.23d |  |
| 143 | 7.10.3.13.6.3 | find solenoid , Vrf , Phase such that waist at YAG02 independent of laser radius |  | 1d | 2007-08-01 | 2007-08-02 |  | 530.23d |  |
| 144 | 7.10.3.13.6.4 | record profile to be used as momentum distribution in model |  | 1d | 2007-08-01 | 2007-08-02 |  | 530.23d |  |
| 145 | 7.10.3.18 | **Steering of beam into L0a** |  | 5d | 2007-08-01 | 2007-08-06 |  | 525.23d |  |
| 146 | 7.10.3.18.5 | **Beam based calibration of BPM2 and BPM3** |  | 2d | 2007-08-01 | 2007-08-03 |  | 525.23d |  |
| 147 | 7.10.3.18.5.3 | low current (100pC) varies SC0, use YAG01/YAG02 and BPM2, BPM3,BPM4 |  | 1d | 2007-08-01 | 2007-08-02 |  | 525.23d | 0d |
| 148 | 7.10.3.18.5.4 | repeat at higher currents (200pC, 500pC, 1nC) |  | 1d | 2007-08-02 | 2007-08-03 | 147 | 525.23d | 0d |
| 149 | 7.10.3.18.6 | determine orthogonality of Ux,Uy knobs (and compare to linear algebra solution) |  | 1d | 2007-08-03 | 2007-08-04 | 148 | 525.23d | 0d |
| 150 | 7.10.3.18.7 | optimize steering at BPM3 and BPM4 (L0a off) |  | 1d | 2007-08-04 | 2007-08-05 | 149 | 525.23d | 0d |
| 151 | 7.10.3.18.8 | optimize steering at BPM3 and BPM4 (L0a on) |  | 1d | 2007-08-05 | 2007-08-06 | 150 | 525.23d | 0d |
| 152 | 7.10.4 | **Optimization of 200pC configuration** |  | 15d | 2007-08-01 | 2007-08-16 |  | 516.23d |  |
| 153 | 7.10.4.7 | Optimize laser pulse for that charge (radius) |  | 1d | 2007-08-06 | 2007-08-07 | 151 | 525.23d |  |
| 154 | 7.10.4.8 | Emittance vs Solenoids (SOL1 and SOL2) |  | 2d | 2007-08-01 | 2007-08-03 |  | 516.23d | 0d |
| 155 | 7.10.4.18 | Emittance vs Bucking Coil |  | 1d | 2007-08-03 | 2007-08-04 | 154 | 516.23d | 0d |
| 156 | 7.10.4.16 | Emittance vs Phase |  | 2d | 2007-08-04 | 2007-08-06 | 155 | 516.23d | 0d |
| 157 | 7.10.4.17 | Emittance vs L0a amplitude |  | 2d | 2007-08-06 | 2007-08-08 | 156 | 516.23d | 0d |
| 158 | 7.10.4.9 | Longitudinal Phase space measurement |  | 1d | 2007-08-08 | 2007-08-09 | 157 | 516.23d | 0d |
| 159 | 7.10.4.10 | Iteration on parameters scanned |  | 4d | 2007-08-09 | 2007-08-13 | 158 | 516.23d | 0d |
| 160 | 5.6.2.8 | adjust correction for Shottky effect (using TCAV) |  | 3d | 2007-08-13 | 2007-08-16 | 159 | 516.23d |  |
| 161 | 5.7 | Injector optimization complete | milestone | 0d | 2007-08-16 | 2007-08-16 | 128 | 593.62d |  |

Notes:
- 136: Limit laser fluence to values less than or equal to values used in step 6 to prevent damage to cathode
- 139: a pulse as short as possible is required for this measurement / find solenoid , Vrf , Phase such that waist at YAG02 independent of laser spot radius
- 140: a detailed tabulation is required for this procedure
- 147: requires the transfer matrix of SC0 in the presence of solenoid
- 149: hopefully use BPM4 (with L0a off) / BPM2,BPM3, BPM4 are required / use YAG01, YAG02 in combination with alignment laser
- 158: for tuning with minimum emittance

| ID | WBS | Task | Type | Duration | Start | Finish | Predecessors | Total slack | Free slack | Constraint | Resources | Work |
| --- | --- | --- | --- | --- | --- | --- | --- | --- | --- | --- | --- | --- |
| 162 | 4 | **2008 Injector re-commissioning** |  | 15d | 2007-12-07 | 2007-12-21 | 251 | 413.6d | 0d |  |  |  |
| 163 | 4.1 | Set-up injector beam again |  | 15d | 2007-12-07 | 2007-12-21 |  | 413.6d |  |  |  |  |
| 164 | 4.2 | Commission laser-heater |  | 5d | 2007-12-07 | 2007-12-11 |  | 423.6d |  |  |  |  |
| 166 | 7 | Linac Commissioning | milestone | 0d | 2006-06-01 | 2006-06-01 |  | 947d |  |  |  |  |
| 167 | 2.14 | Ready for Beam to BC1 (TD11) | milestone | 0d | 2007-03-16 | 2007-03-16 |  | 542.98d | 28.75d | start no earlier than 2007-03-16 |  |  |
| 168 | LC01 | **Beam to TD11 stopper (after BC1)** |  | 128.62d | 2007-04-13 | 2007-08-20 | 167 | 514.23d |  |  | Linac; Injector; Drive Laser | 2175h |
| 169 | 9.1 | **First Pass Commissioning/beam to TD11** |  | 31.88d | 2007-04-13 | 2007-05-15 | 87 | 514.23d | 0d |  |  |  |
| 170 | 9.1.1 | **Establish beam on TD11** |  | 6.12d | 2007-04-13 | 2007-04-19 |  | 514.23d |  |  |  |  |
| 171 | 47 | Turn ON BX01/BX02 (e- into L1) |  | 2h | 2007-04-13 | 2007-04-13 |  | 514.23d | 0d |  |  |  |
| 172 | 04 | Time BPMs to beam while steering |  | 1d | 2007-04-14 | 2007-04-14 | 171 | 514.23d | 0d |  |  |  |
| 173 | 05 | Rough steer to TD11 |  | 1d | 2007-04-15 | 2007-04-15 | 172 | 514.23d | 0d |  |  |  |
| 174 | 5.1.4.3 | Measure Gallery Radiation, beam to TD11 |  | 5h | 2007-04-16 | 2007-04-16 | 173 | 514.23d | 0d |  |  |  |
| 175 | 44 | Set timing/calibrate toroids |  | 1d | 2007-04-16 | 2007-04-16 | 173 | 542.85d |  |  |  |  |
| 176 | 53 | Checkout DL1 toroid MPS comparator |  | 1d | 2007-04-16 | 2007-04-16 | 173 | 542.85d |  |  |  |  |
| 177 | 49 | Linac access to fix problems |  | 1d | 2007-04-16 | 2007-04-17 | 174 | 514.23d | 0d |  |  |  |
| 178 | 9.1.1.8 | Turn ON BC1 and steer |  | 1d | 2007-04-17 | 2007-04-18 | 177 | 514.23d | 0d |  |  |  |
| 179 | 18 | Checkout BC1 toroid MPS comparator |  | 1d | 2007-04-18 | 2007-04-19 | 178 | 514.23d | 0d |  |  |  |
| 180 | 06 | Calibrate x-scale of BC1 BPM |  | 2h | 2007-04-19 | 2007-04-19 | 179 | 514.23d | 0d |  |  |  |
| 181 | 9.1.2 | **Verify Optics, Calibrate, and Phase** |  | 25.75d | 2007-04-19 | 2007-05-15 | 180 | 514.23d |  |  |  |  |
| 182 | 41 | Roughly verify optics, BPMs, etc |  | 2d | 2007-04-19 | 2007-04-21 |  | 514.23d | 0d |  |  |  |
| 183 | 62 | Linac access to fix problems |  | 1d | 2007-04-21 | 2007-04-22 | 182 | 514.23d | 0d |  |  |  |
| 184 | 07 | Calibrate L1 S-band phase shifter |  | 4h | 2007-04-22 | 2007-04-23 | 183 | 514.23d | 0d |  |  |  |
| 185 | 08 | Set RF phase of L1 klystron |  | 4h | 2007-04-23 | 2007-04-23 | 184 | 514.23d | 0d |  |  |  |
| 186 | 38 | **Turn ON X-band RF systems** |  | 3.5d | 2007-04-23 | 2007-04-27 | 185 | 514.23d | 0d |  |  |  |
| 187 | 9.1.2.5.1 | Call RF tech's and bring up X-band RF |  | 1d | 2007-04-23 | 2007-04-24 |  | 514.23d | 0d |  |  |  |
| 188 | 9.1.2.5.2 | Dial phase quickly to approx. decel. crest |  | 2h | 2007-04-24 | 2007-04-25 | 187 | 514.23d | 0d |  |  |  |
| 189 | 9.1.2.5.3 | Increase L1 amp. 19 MV to comp. X-band |  | 2h | 2007-04-25 | 2007-04-25 | 188 | 514.23d | 0d |  |  |  |
| 190 | 9.1.2.5.4 | Do system tests as required |  | 2d | 2007-04-25 | 2007-04-27 | 189 | 514.23d |  |  |  |  |
| 191 | 29 | Calibrate L1 X-band phase shifter |  | 4h | 2007-04-27 | 2007-04-27 | 186 | 514.23d | 0d |  |  |  |
| 192 | 09 | Set RF phase of LX klystron |  | 4h | 2007-04-27 | 2007-04-28 | 191 | 514.23d | 0d |  |  |  |
| 193 | 10 | Confirm and correct X-band voltage |  | 4h | 2007-04-28 | 2007-04-28 | 192 | 514.23d | 0d |  |  |  |
| 194 | 11 | Set proper energy in BC1 chicane |  | 2h | 2007-04-28 | 2007-04-29 | 193 | 514.23d | 0d |  |  |  |
| 195 | 14 | Take precision "oscillation" data |  | 1d | 2007-04-29 | 2007-04-30 | 194 | 514.23d | 0d |  |  |  |
| 196 | 42 | Linac access to fix problems |  | 1d | 2007-04-30 | 2007-05-01 | 195 | 514.23d | 0d |  |  |  |
| 197 | 43 | Take precision "oscillation" data |  | 1d | 2007-05-01 | 2007-05-02 | 196 | 514.23d | 0d |  |  |  |
| 198 | 15 | Careful steering through L1/BC1 |  | 1d | 2007-05-02 | 2007-05-03 | 197 | 514.23d | 0d |  |  |  |
| 199 | 17 | Calibrate BPM intensities to toroid |  | 4h | 2007-05-03 | 2007-05-03 | 198 | 514.23d | 0d |  |  |  |

Notes:
- 168: GOALS: / ====== / Transport beam through system to 250 MeV, establishing initial trajectory, energy, energy spread, and bunch length. Verify MPS systems, checkout and calibrate beam diagnostics, and make first emittance measurements in this system. / CONDITIONS: / =========== / Injector, up to SAB, has been commissioned to a reasnable degree with no major limitations. Bunch charge is 0.2-0.5 nC, rate is at least 1 Hz (up to 30 Hz), RF systems in L1 and X-band are ready and available.
- 169: X-band OFF, L1 S-band ON, BC1 OFF
- 172: Step BPM timing in 8-ns steps to find beam on each BPM - save timing.
- 173: Rough steering of beam through L1/BC1 / ·Leave X-band off, BC1 ON, initially / ·Measure BPMs up to BPM21301 / ·Empirically adjust correctors up to XCM13 and YCM12 / ·Monitor ion-chambers, PLIC, etc for beam loss / ·Adjust L1-RF phase and voltage if necessary (BPMS11=0) / ·Confirm beam on TD11 dump screen, if available
- 174: Measure radiation in gallery near penetrations 21-3,21-4,21-5, 21-6 with e- parked on TD11, and calibrate LION2A & LION2B
- 175: Set timing and calibrate toroids IM03, IMBC1I, and IMBC1O
- 176: Checkout MPS toroid comparator across DL1: / ·Compare and trip MPS as IM03/IM02 < ~0.9 (?) / ·Induce beam loss in DL1 with OTR4?
- 179: Checkout MPS toroid comparator across BC1: / ·Compare and trip MPS as IMBC1O/IMBC1I < ~0.9 (?) / ·Induce beam loss in BC1 with collimator CE11
- 180: Calibrate x-scale of BPMS11 in BC1 chicane: / ·Measure BPMS11 x-position and chicane mover LVDT / ·Scan mover settings of BC1 chicane displacement
- 182: Take brief osc. data through beamline to find gross errors
- 184: Calibrate L1 S-band RF phase shifter: / ·Measure BPMS11 in BC1 chicane / ·Scan L1 RF phase 360 degrees to find nodes
- 185: Set RF phase for L1 klystron: / ·Measure BPMS11 in BC1 chicane / ·Scan L1 RF phase around crest (set to -25 deg)
- 187: 19 MV at ~180 deg for 1 nC
- 191: Calibrate X-band RF phase shifter: / ·Measure BPMS11 in BC1 chicane / ·Scan X-band RF phase 360 degrees to find nodes
- 192: Set RF phase for LX klystron: / ·Measure BPMS11 in BC1 chicane / ·Scan LX RF phase around crest (set to -160 deg)
- 193: Confirm and correct X-band voltage: / ·Scan X-band klystron voltage / ·Measure BPMS11 change
- 194: Set proper energy in BC1 chicane: / ·Set BPMS11 x » 0 (+- 0.2 mm) / ·Set L1 voltage
- 195: Confirm linear optics, BPM scaling, and correctors with respect to on-line model: / ·Measure difference orbit of all BPMs up to BPM21301 / ·Scan all correctors from XC10/YC10 to XCM11/YC21201
- 197: Confirm linear optics, BPM scaling, and correctors with respect to on-line model: / ·Measure difference orbit of all BPMs up to BPM21301 / ·Scan all correctors from XC10/YC10 to XCM11/YC21201
- 198: Careful steering of beam through L1/BC1 (software checkout?): / ·Measure BPMs up to BPM21301 / ·Automated adjustment of correctors up to XCM13 and YCM12
- 199: Calibrate BPM intensities w.r.t. toroid IMBC1I

| ID | WBS | Task | Type | Duration | Start | Finish | Predecessors | Total slack | Free slack |
| --- | --- | --- | --- | --- | --- | --- | --- | --- | --- |
| 200 | 9.1.2.15 | **Checkout Screens & BLM** |  | 12d | 2007-05-03 | 2007-05-15 | 199 | 514.23d |  |
| 201 | 9.1.2.15.1 | Setup and test WS4 |  | 2d | 2007-05-03 | 2007-05-05 |  | 514.23d | 0d |
| 202 | 9.1.2.15.2 | Setup and test OTR4 |  | 2d | 2007-05-05 | 2007-05-07 | 201 | 514.23d | 0d |
| 203 | 9.1.2.15.3 | **Setup and test OTR11** |  | 2d | 2007-05-07 | 2007-05-09 | 202 | 514.23d | 0d |
| 204 | 9.1.2.15.3.1 | Calibrate x-scale of BC1 OTR |  | 2d | 2007-05-07 | 2007-05-09 |  | 514.23d |  |
| 205 | 9.1.2.15.4 | Setup and test OTR12 |  | 2d | 2007-05-09 | 2007-05-11 | 203 | 514.23d | 0d |
| 206 | 56 | Measure energy spread in BC1 |  | 1d | 2007-05-11 | 2007-05-12 | 205 | 514.23d | 0d |
| 207 | 45 | Look for BL11 & BL12 bunch length signals |  | 3d | 2007-05-12 | 2007-05-15 | 206 | 514.23d | 0d |
| 208 | 9.2 | Linac beam ready on TD11 | milestone | 0d | 2007-05-15 | 2007-05-15 | 207 | 686.38d |  |
| 209 | 9.3 | **Second Pass Commissioning/characterization** |  | 40.25d | 2007-06-22 | 2007-08-01 | 88 | 516.23d | 0d |
| 210 | 9.3.1 | **Minimize DL1 energy spread** |  | 1d | 2007-06-22 | 2007-06-23 |  | 516.23d | 0d |
| 211 | 9.3.1.1 | Check with simulation result |  | 1d | 2007-06-22 | 2007-06-23 |  | 516.23d |  |
| 212 | 61 | Linac access to fix problems |  | 2d | 2007-06-23 | 2007-06-25 | 210 | 516.23d | 0d |
| 213 | 9.3.3 | **Setup DL1 launch feedback** |  | 2.5d | 2007-06-25 | 2007-06-27 | 212 | 516.23d | 0d |
| 214 | 9.3.3.1 | Test feedback step response |  | 4h | 2007-06-25 | 2007-06-25 |  | 516.23d | 0d |
| 215 | 9.3.3.2 | Debug feedback code |  | 2d | 2007-06-25 | 2007-06-27 | 214 | 516.23d |  |
| 216 | 9.3.4 | **Setup energy feedback on L0/DL1** |  | 3.25d | 2007-06-27 | 2007-06-30 | 213 | 516.23d | 0d |
| 217 | 9.3.4.1 | Careful steer BPM9-15 |  | 2h | 2007-06-27 | 2007-06-27 |  | 516.23d | 0d |
| 218 | 9.3.4.2 | Calibrate BPM13 X-readback |  | 2h | 2007-06-27 | 2007-06-28 | 217 | 516.23d | 0d |
| 219 | 9.3.4.3 | Verify optics from BPM9-15 |  | 4h | 2007-06-28 | 2007-06-28 | 218 | 516.23d | 0d |
| 220 | 9.3.4.4 | Save feedback reference orbit | milestone | 0h | 2007-06-28 | 2007-06-28 | 219 | 516.23d | 0d |
| 221 | 9.3.4.5 | Test feedback step response |  | 2h | 2007-06-28 | 2007-06-28 | 220 | 516.23d | 0d |
| 222 | 9.3.4.6 | Debug feedback code |  | 2d | 2007-06-28 | 2007-06-30 | 221 | 516.23d |  |
| 223 | 30 | **Setup longitudinal feedback on L1/BC1** |  | 5.25d | 2007-06-30 | 2007-07-06 | 216 | 516.23d | 0d |
| 224 | 30.22 | Establish approx. S & X-band phases |  | 4h | 2007-06-30 | 2007-07-01 |  | 516.23d | 0d |
| 225 | 30.18 | Save feedback reference orbit |  | 2h | 2007-07-01 | 2007-07-01 | 224 | 516.23d | 0d |
| 226 | 30.20 | Test feedback step response |  | 4h | 2007-07-01 | 2007-07-02 | 225 | 516.23d | 0d |
| 227 | 30.21 | Debug feedback code |  | 4d | 2007-07-02 | 2007-07-06 | 226 | 516.23d |  |
| 228 | 63 | Linac access to fix problems |  | 1d | 2007-07-06 | 2007-07-07 | 223 | 516.23d | 0d |
| 229 | 9.3.7 | Test TCAV0 bunch-length meas. sofware |  | 2d | 2007-07-07 | 2007-07-09 | 228 | 516.23d | 0d |
| 230 | 9.3.8 | Beam-base align critical quadrupoles |  | 1d | 2007-07-09 | 2007-07-10 | 229 | 516.23d | 0d |
| 231 | 31 | Center CE11 collimator in BC1 |  | 2h | 2007-07-10 | 2007-07-10 | 230 | 516.23d | 0d |
| 232 | 58 | Record machine stability (traj, charge, etcx) |  | 8h | 2007-07-10 | 2007-07-11 | 231 | 516.23d | 0d |
| 233 | 22 | Checkout post-BC1 wire scanners |  | 8h | 2007-07-11 | 2007-07-12 | 232 | 516.23d | 0d |
| 234 | 59 | Checkout post-BC1 OTR12 |  | 8h | 2007-07-12 | 2007-07-13 | 233 | 516.23d | 0d |
| 235 | 23 | Meas. post-BC1 x/y emit. with wires |  | 1d | 2007-07-13 | 2007-07-14 | 234 | 516.23d | 0d |
| 236 | 25 | Meas. post-BC1 x/y emit. with OTR12 |  | 1d | 2007-07-14 | 2007-07-15 | 235 | 516.23d | 0d |
| 237 | 35 | Meas. slice emittance on BC1 OTR11 |  | 2d | 2007-07-15 | 2007-07-17 | 236 | 516.23d | 0d |
| 238 | 9.3.16 | Take e- to end of linac on SL2 |  | 1d | 2007-07-17 | 2007-07-18 | 237 | 516.23d | 0d |
| 239 | 9.3.17 | Setup sec-29 TCAV to meas. bunch length |  | 3d | 2007-07-18 | 2007-07-21 | 238 | 516.23d | 0d |
| 240 | 9.3.18 | Commission BL11 & BL12 bunch length monitors |  | 3d | 2007-07-21 | 2007-07-24 | 239 | 516.23d | 0d |
| 241 | 65 | Linac access to fix problems |  | 1d | 2007-07-24 | 2007-07-25 | 240 | 516.23d | 0d |
| 242 | 9.3.20 | Commission BL11 & BL12 bunch length monitors |  | 3d | 2007-07-25 | 2007-07-28 | 241 | 516.23d | 0d |
| 243 | 9.3.21 | Demonstrate bunch length vs. L1 phase |  | 2d | 2007-07-28 | 2007-07-30 | 242 | 516.23d | 0d |
| 244 | 9.3.22 | Do CSR studies in BC1 |  | 2d | 2007-07-30 | 2007-08-01 | 243 | 516.23d | 0d |
| 245 | 9.4 | Linac beam characterized to TD11 | milestone | 0d | 2007-08-01 | 2007-08-01 | 244 | 608.62d |  |

Notes:
- 204: Calibrate x-scale of OTR11 screen in BC1 chicane: / ·Measure OTR11 mean x-position and chicane mover LVDT / ·Scan mover settings of BC1 chicane displacement
- 206: Measure energy spread in BC1: / ·Measure horizontal beam size on OTR11 screen in BC1 / ·Vary L1 RF phase (only if injector bunch length is set properly)
- 207: Look for CSR signal on BL11 bunch length monitor: / - time device to beam, if necessary / - adjust attenuators, polarizers, rad-collimators / - Adjust L1 or Lx RF phase to look for sensitivity / - Measure signal to noise ratio, if possible / - Prepare all data for next access
- 210: Minimize DL1 energy spread: / ·Scan L0b RF phase / ·Minimize x-beam size on OTR4 or WS04 (or YAGS2) where etaX = 166 mm (etaX = 900 mm).
- 211: After the L0 RF phase is set, check the longitudinal phase spcae with simulation results.
- 213: Follow steps below to commission L0-DL1 launch feedback loop. / The feedback loop adjusts XC04/07, YC04/07 and uses BPM9-15 to measure the beam position and angle in x and y
- 214: Test step-function response of feedback loop: / ·Change beam launch with XC03 & YC03 (& XC02, YC02?) / ·Record response vs. time of feedback loop signal / ·Verify L0b voltage changes do not affect launch, etc
- 215: Debug beam-based feedback code, at least for this L0-DL1 launch loop.
- 216: Follow steps below to commission DL1 energy feedback loop / The feedback loop adjusts L0b RF voltage and uses BPM9-15 to measure the beam energy (263 mm dispersion on BPM13)
- 218: Calibrate x-scale of BPM13 between DL1 bends: / ·Measure BPM13 x-position (263 mm dispersion) / ·Scan L0b RF voltage a known amount
- 219: Verify optics from XC04 through BPM15 (feedback range): / ·Measure BPM9-15, x & y / ·Scan XC04, YC04, XC07, YC07 / ·Ensure optics matches model / ·Fix any problems before proceeding
- 220: Save reference orbit from BPM9-15 for feedback goal: / ·Measure BPM9-15 x & y/ ·Save reference file of readings into feedback ref. file
- 221: Test step-function response of feedback loop: / ·Change beam energy with L0a or L0b klytrons voltage or phase / ·Record response vs. time of feedback loop signal (BPM13) / ·Verify XC04/07, YC04/07 changes do not affect energy, etc
- 222: Debug beam-based feedback code, at least for this DL1 energy loop.
- 223: Follow steps below to commission BC1 energy/bunch-length feedback loop / The feedback loop adjusts L1 RF voltage and phase and uses BPMS13, BPM15, BPM21201 to measure the beam energy (231 mm dispersion on BPMS11) and BL11 CSR detector to measure relative bunch length
- 225: Save reference orbit from BPM15-BPM21201 for feedback goal: / ·Measure BPM15-BPM21201 x & y/ ·Save reference file of readings into feedback ref. file
- 226: Test step-function response of feedback loop: / ·Change beam energy with L0/DL1 loop setpoint / ·Record response vs. time of feedback loop energy signal (BPMS11) / ·Change bunch length with L1 RF phase / ·Record response vs. time of feedback loop bunch length signal (BL11) / ·Verify XC04/07, YC04/07 changes do not affect energy or bunch length, etc
- 227: Debug beam-based feedback code, at least for this BC1 loop.
- 229: Test new software designed to make fast bunch length measurements using the transverse deflecting RF cavity. / The software should set the TCAV0 phase to each zero-crossing point, plus TCAV0-off, and measure the vertical beam size on OTR2 or WS02, then fit a parabola to these 3 points, and from this calculate the bunch length. The software must also have a calibrate function which will also be used to calibrate the vertical screen pixels into S-band degrees by varying the RF phase around the zero crossing and linearly fitting the beam centroid on the screen.
- 230: Apply beam-based alignment to several critical quadrupole magnets: / ·Measure BPM variations vs. quadrupole gradients / ·Use linear fit to calculate misalignment (x and y) / ·Steer beam to center (or schedule tunnel alignment if > ~1 mm) / ·Document changes / ·Do at least for quadrupoles: Q21201, QM11, QM12, QM13 / ·Pay special attention to QM12 vertical alignment (minimize y-emit?)
- 231: Center CE11 collimator on beam in BC1 chicane: / ·Measure beam loss on ratio: IMBC1O/IMBC1I / ·Scan each collimator jaw to produce 5-10% loss / ·Retract each collimator jaw 45 mm from beam
- 233: Checkout wire scanners: WS11, WS12, and WS13: / ·Measure beam x and y centers on each wire / ·Scan the precision-calibrated correctors: XCA12(?) and YCA11
- 234: Checkout OTR screen after BC1: OTR12: / ·Measure beam x and y center / ·Scan the precision-calibrated correctors: XCA12(?) and YCA11
- 235: Measure x and y emittance with wire-scanners after BC1 / ·Measure beam x and y rms size on wires: WS11, WS12, and WS13 / ·Calculate ge- and Bmag and adjust match with QM11(x),12(y), and 13 / ·Check out software?
- 236: Measure x and y emittance after BC1 with quad scan on OTR12: / ·Measure beam x and y rms size on screen: OTR12 / ·Calculate ge- and Bmag/ ·Check out software?
- 237: Measure y slice-emittance in BC1 with quad scan on OTR11: / ·Measure beam y rms size vs. x-slice on screen OTR11 / ·Calculate ge- and Bmag for each x-slice / ·Check out slice-emit software
- 238: - Take e- beam through to end of linac onto SL2 stoppers at 4-14 GeV / - Adjust LEM and steer
- 244: Perform CSR experiments in BC1: / - Vary L1 RF phase and/or X-band phase / - Monitor CSR signals and debug

| ID | WBS | Task | Type | Duration | Start | Finish | Predecessors | Total slack | Free slack | Constraint | Resources | Work |
| --- | --- | --- | --- | --- | --- | --- | --- | --- | --- | --- | --- | --- |
| 246 | 9.5 | **Third-Pass Commissioning/beam to SL2** |  | 4d | 2007-08-16 | 2007-08-20 | 128 | 516.23d |  |  |  |  |
| 247 | 9.5.1 | Do CSR studies in BC1 |  | 2d | 2007-08-16 | 2007-08-18 |  | 516.23d | 0d |  |  |  |
| 248 | 9.5.2 | Do BBA tests through to BSY |  | 2d | 2007-08-18 | 2007-08-20 | 247 | 516.23d | 0d |  |  |  |
| 249 | 9.6 | Gun to BC1 Commissioning Complete | milestone | 0d | 2007-08-20 | 2007-08-20 | 248 | 516.23d | 102.62d |  |  |  |
| 250 | 2.31.2 | End Fall 2007 Downtime | milestone | 0d | 2007-12-01 | 2007-12-01 |  | 0d |  | must start on 2007-12-01 |  |  |
| 251 | LC08 | **Pre-Beam Checkout to TD21 (after BC2)** |  | 6d | 2007-12-01 | 2007-12-06 | 249, 250 | 413.6d | 0d |  |  |  |
| 252 | LC08.05 | Verify location of all critical components |  | 2d | 2007-12-01 | 2007-12-02 |  | 413.6d | 0d |  |  |  |
| 253 | 11.2 | Verify water flow where possible |  | 1d | 2007-12-03 | 2007-12-03 | 252 | 413.6d | 0d |  |  |  |
| 254 | LC08.06 | Exercise all motion-controlled devices |  | 1d | 2007-12-04 | 2007-12-04 | 253 | 413.6d | 0d |  |  |  |
| 255 | LC08.07 | Verify all OTR camera images |  | 1d | 2007-12-05 | 2007-12-05 | 254 | 413.6d | 0d |  |  |  |
| 256 | LC08.08 | Verify polarity of all magnets |  | 1d | 2007-12-06 | 2007-12-06 | 255 | 413.6d |  |  |  |  |
| 257 | LC02 | **Beam to TD21 stopper (after BC2)** |  | 16.25d | 2007-12-21 | 2008-01-07 | 248, 289, 162 | 413.6d | 0d |  | Linac; Drive Laser; Injector | 204h |
| 258 | LC02.01 | Start Linac (Li20-Li30) Commissioning | milestone | 0d | 2007-12-21 | 2007-12-21 |  | 413.6d | 0d |  |  |  |
| 259 | LC02.05 | Time BPMs to beam |  | 2h | 2007-12-22 | 2007-12-22 | 258 | 413.6d | 0d |  |  |  |
| 260 | 12.3 | Rough steering of beam to PRTD21 |  | 1d | 2007-12-22 | 2007-12-23 | 259 | 413.6d | 0d |  |  |  |
| 261 | LC02.11 | Checkout BC2 MPS toroid comparator |  | 4h | 2007-12-23 | 2007-12-23 | 260 | 413.6d | 0d |  |  |  |
| 262 | LC02.02 | Calibrate x-scale of BC2 BPM |  | 2h | 2007-12-23 | 2007-12-23 | 261 | 413.6d | 0d |  |  |  |
| 263 | LC02.35 | Phase all L2 klystrons ??? |  | 1d | 2007-12-24 | 2007-12-24 | 262 | 413.6d | 0d |  |  |  |
| 264 | LC02.33 | Calibrate 24-5 & 24-6 S-band phase shifters |  | 3h | 2007-12-25 | 2007-12-25 | 263 | 413.6d | 0d |  |  |  |
| 265 | LC02.03 | Set RF phase for L2 klystron |  | 4h | 2007-12-25 | 2007-12-25 | 264 | 413.6d | 0d |  |  |  |
| 266 | LC02.06 | Set proper energy in BC2 chicane |  | 1h | 2007-12-25 | 2007-12-25 | 265 | 413.6d | 0d |  |  |  |
| 267 | LC02.07 | Take "oscillation" data |  | 1d | 2007-12-26 | 2007-12-26 | 266 | 413.6d | 0d |  |  |  |
| 268 | LC02.08 | Careful steer through L2/BC2 |  | 1d | 2007-12-27 | 2007-12-27 | 267 | 413.6d | 0d |  |  |  |
| 269 | LC02.09 | Set timing/calibrate toroids |  | 4h | 2007-12-28 | 2007-12-28 | 268 | 413.6d | 0d |  |  |  |
| 270 | LC02.10 | Calibrate BPMs w.r.t. toroid |  | 2h | 2007-12-28 | 2007-12-28 | 269 | 413.6d | 0d |  |  |  |

Notes:
- 247: Perform CSR experiments in BC1: / - Vary L1 RF phase and/or X-band phase / - Measure bunch length on sec-29 TCAV / - Measure emittance on WS11,12,13 & slice on OTR12 if possible (new optics?) / - Measure emittance with over-compression in BC1 / - Measure emittance with X-band off for head-spike after BC1, etc
- 248: Perform early BBA energy scaling tests with e- on SL2 / - Set energy at 14, 7, and 4.3 GeV if possible scaling all 25-BSY magnets / - Measure trajectory / - Study problems with procedure / - Save configuration files at each setting
- 252: In tunnel: / -measure z-location of all quadrupoles, dipoles, correctors, BPMs, collimators, wire-scanners, OTR/YAG screens / -Visually inspect terminal connections to magnets / -Verify cable labels match magnets / -Remove mis-laid tools, etc
- 254: Exercise full range motion-control for all: / -wire-scanners (WS21,22,23,24) / -YAG/OTR insertable screens (OTR21) / -insertable tune-up dumps (TD21) / -collimators (CE21) / -make sure all are removed (except TD21?) before beam ON
- 255: Verify image of OTR/CrO insertable screens: / -OTR21 (BC2) / -PR21 (on TD21)
- 256: With power on access: / -Possibly probe-eye all magnet terminals at nominal settings / -Test polarity of all quadrupoles, dipoles, and correctors / -Use flipper coil or Hall probe
- 257: GOALS: / ====== / Transport beam through system to 4.3 GeV, establishing initial trajectory, energy, energy spread, and bunch length. Verify MPS systems, checkout and calibrate beam diagnostics, and make first emittance measurements in this system.
- 259: Step BPM timing in 8-ns steps to find beam on each BPM - save timing.
- 260: Rough steering of beam through L2/BC2: / ·Measure BPMs up to BPM24901 / ·Empirically adjust correctors up to XC24701 and YC24701 (XC24702 and YC24703 in MAC deck) / ·Confirm beam on PRTD12 screen
- 261: Checkout MPS toroid comparator across BC2: / ·Compare and trip MPS as IMBC2O/IMBC2I < ~0.9 (?) / ·Induce beam loss in BC2 with collimator CE21
- 262: Calibrate x-scale of BPMS11 in BC2 chicane: / ·Measure BPMS21 x-position and chicane mover LVDT(?) / ·Scan mover settings of BC2 chicane displacement
- 264: Calibrate 24-5 & 24-6 S-band RF phase shifters: / ·Measure BPMS21 in BC1 chicane / ·Scan 24-5 & then 24-6 RF phase 360 degrees to find nodes
- 265: Set RF phase for L2 klystron: / ·Measure BPMS21 in BC2 chicane / ·Scan L2 RF phase around crest (set to -41 deg)
- 266: Set proper energy in BC2 chicane: / ·Set BPMS21 » 0 / ·Set L2 voltage
- 267: Confirm linear optics, BPM scaling, and correctors with respect to on-line model / ·Measure difference orbit of all BPMs up to BPM24701 / ·Scan all correctors from XCM13/YCM12 to XC24701/YC24701
- 268: Careful steering of beam through L2/BC2 (software checkout?): / ·Measure BPMs up to BPMS21 / ·Automated adjustment of correctors up to XC24901 and YC24901 (after BC2END? )
- 269: Set timing and calibrate toroids IMBC2I, and IMBC2O
- 270: Calibrate BPM intensities w.r.t. toroid IMBC2I

| ID | WBS | Task | Duration | Start | Finish | Predecessors | Total slack | Free slack |
| --- | --- | --- | --- | --- | --- | --- | --- | --- |
| 271 | LC02.17 | **Setup longitudinal feedback on L2** | 1.88d | 2007-12-28 | 2007-12-30 | 270 | 413.6d | 0d |
| 272 | LC02.17.25 | Save feedback reference orbit | 2h | 2007-12-28 | 2007-12-28 |  | 413.6d | 0d |
| 273 | LC02.17.26 | Switch on feedback | 1h | 2007-12-29 | 2007-12-29 | 272 | 413.6d | 0d |
| 274 | LC02.17.27 | Test feedback step response | 4h | 2007-12-29 | 2007-12-29 | 273 | 413.6d | 0d |
| 275 | LC02.17.28 | Debug feedback code | 1d | 2007-12-29 | 2007-12-30 | 274 | 413.6d |  |
| 276 | 12.15 | Beam-base align critical quadrupoles | 1d | 2007-12-30 | 2007-12-31 | 271 | 413.6d | 0d |
| 277 | LC02.18 | **Setup launch feedback in L2** | 1.88d | 2007-12-31 | 2008-01-02 | 276 | 413.6d | 0d |
| 278 | LC02.18.08 | Save feedback reference orbit | 2h | 2007-12-31 | 2007-12-31 |  | 413.6d | 0d |
| 279 | LC02.18.09 | Switch on feedback | 1h | 2007-12-31 | 2007-12-31 | 278 | 413.6d | 0d |
| 280 | LC02.18.10 | Test feedback step response | 4h | 2008-01-01 | 2008-01-01 | 279 | 413.6d | 0d |
| 281 | LC02.18.11 | Debug feedback code | 1d | 2008-01-01 | 2008-01-02 | 280 | 413.6d |  |
| 282 | LC02.19 | Center CE21 collimator in BC2 | 2h | 2008-01-02 | 2008-01-02 | 277 | 413.6d | 0d |
| 283 | 12.18 | Setup PRTD21 screen | 4h | 2008-01-02 | 2008-01-03 | 282 | 413.6d | 0d |
| 284 | LC02.12 | Calibrate x-scale of BC2 OTR | 4h | 2008-01-03 | 2008-01-03 | 283 | 413.6d | 0d |
| 285 | LC02.13 | Measure energy spread in BC2 | 4h | 2008-01-03 | 2008-01-04 | 284 | 413.6d | 0d |
| 286 | LC02.36 | Measure residual dispersion after BC1 | 1d | 2008-01-04 | 2008-01-05 | 285 | 413.6d | 0d |
| 287 | LC02.14 | Checkout pre-BC2 wire scanners | 1d | 2008-01-05 | 2008-01-06 | 286 | 413.6d | 0d |
| 288 | LC02.15 | Meas. x/y emit. with pre-BC2 wires | 1d | 2008-01-06 | 2008-01-07 | 287 | 413.6d |  |
| 289 | LC09 | **Pre-Beam Checkout to SL2 (in BSY)** | 6d | 2007-12-01 | 2007-12-06 | 250 | 428.6d | 15d |
| 290 | LC09.09 | Verify location of all critical components | 2d | 2007-12-01 | 2007-12-02 |  | 428.6d | 0d |
| 291 | 13.2 | Verify water flow where possible | 1d | 2007-12-03 | 2007-12-03 | 290 | 428.6d | 0d |
| 292 | LC09.10 | Exercise all motion-controlled devices | 1d | 2007-12-04 | 2007-12-04 | 291 | 428.6d | 0d |
| 293 | LC09.11 | Verify all OTR camera images | 1d | 2007-12-05 | 2007-12-05 | 292 | 428.6d | 0d |
| 294 | LC09.12 | Verify polarity of all magnets | 1d | 2007-12-06 | 2007-12-06 | 293 | 428.6d |  |

Notes:
- 271: Follow steps below to commission BC2 energy/bunch-length feedback loop / The feedback loop adjusts 24-5 and 24-6 klystron opposing phases and voltages and uses BPMS21, BPM24401, BPM24601 to measure the beam energy (363 mm dispersion on BPMS21) and BL21 CSR detector to measure relative bunch length
- 272: Save ref. orbit from BPM24401, BPM24601, and BPMS21 for feedback goal: / ·Measure BPM24401, BPM24601, BPMS21 x & y/ ·Save reference file of readings into feedback ref. file
- 274: Test step-function response of feedback loop: / ·Change beam energy with 24-5/6 klytrons voltage or phase / ·Record response vs. time of feedback loop energy signal (BPMS21) / ·Change bunch length with L1 RF phase / ·Record response vs. time of feedback loop bunch length signal (BL21) / ·Verify XC21402, XC21802, YC21503, YC21900 changes do not affect energy or bunch length, etc
- 275: Debug beam-based feedback code, at least for this BC2 longitudinal loop.
- 276: Apply beam-based alignment to several critical quadrupole magnets: / ·Measure BPM variations vs. quadrupole gradients / ·Use linear fit to calculate misalignment (x and y) / ·Steer beam to center (or schedule tunnel alignment if > ~1 mm) / ·Document changes / ·Do at least for quadrupoles: QM14, QM15, Q24701A/B, QM21 (Q24701A/B on same power supply)
- 277: Follow steps below to commission L2 launch feedback loop. / The feedback loop adjusts XC21402, XC21802, YC21503, and YC21900 and uses BPM21901-BPM23501 to measure the beam position and angle in x and y
- 278: Save reference orbit from BPM21901-BPM23501 for feedback goal: / ·Measure BPM21901-BPM23501 x & y/ ·Save reference file of readings into feedback ref. file
- 280: Test step-function response of feedback loop: / ·Change beam launch with XC21402, XC21802, YC21503, YC21900 / ·Record response vs. time of feedback loop signal / ·Verify 24-5/6 klystron RF voltage changes do not affect launch, etc
- 281: Debug beam-based feedback code, at least for this L2 launch loop.
- 282: Center CE21 collimator on beam in BC2 chicane: / ·Measure beam loss on ratio: IMBC2O/IMBC2I / ·Scan each collimator jaw to produce 5-10% loss / ·Retract each collimator jaw 36 mm from beam
- 283: Setup beam on Tune-up-Dump screen, PRTD21, after BC2 chicane: / ·Setup video systems / ·Move beam to estimate calibration, etc?
- 284: Calibrate x-scale of OTR21 screen in BC2 chicane: / ·Measure OTR21 mean x-position and chicane mover LVDT / ·Scan mover settings of BC2 chicane displacement
- 285: Measure energy spread in BC2: / ·Measure horizontal beam size on OTR21 screen in BC2 / ·Vary L2 RF phase (only if injector bunch length is set properly)
- 286: Measure residual x and y dispersion just after BC1: / ·Measure x & y BPMs from BPMS11 to BPM21901 / ·Vary BC1 energy setpoint +-2% / ·Correlate BPMS11/etaX with BPM x & y readings / ·Correct x dispersion with CQ11 & CQ12
- 287: Checkout pre-BC2 wire scanners: WS21, WS22, WS23, and WS24: / ·Measure beam x and y centers on each wire / ·Scan the precision-calibrated correctors: XC24702 and YC24703
- 288: Measure x and y emittance with wire-scanners after BC1: / ·Measure beam x and y rms size on wires: WS21, WS22, WS13, and WS24 / ·Calculate ge- and Bmag and adjust match with QM21(x?), and 22(y?) / ·Check out software?
- 290: In tunnel: / -measure z-location of all quadrupoles, dipoles, correctors, BPMs, collimators, wire-scanners, OTR/YAG screens / -Visually inspect terminal connections to magnets / -Verify cable labels match magnets / -Remove mis-laid tools, etc
- 292: Exercise full range motion-control for all: / -wire-scanners (WS044,144,444,544,WS62-BSY) / -OTR insertable screens (OTR_TCAV) / -collimators (C29096,C29146,C29446,C29546,C30096,C30146,C30446,C30546,SL1,SL2?) / -make sure all are removed (except SL1,SL2?) before beam ON
- 293: Verify image of OTR/CrO insertable screens: / -OTR_TCAV (25-9) / -PR52 (BSY)
- 294: With power on access: / -Possibly probe-eye all magnet terminals at nominal settings / -Test polarity of all quadrupoles, dipoles, and correctors / -Use flipper coil or Hall probe

| ID | WBS | Task | Type | Duration | Start | Finish | Predecessors | Total slack | Free slack | Constraint |
| --- | --- | --- | --- | --- | --- | --- | --- | --- | --- | --- |
| 295 | LC03 | **Beam to end of linac on SL2 (50B1 on)** |  | 13.12d | 2008-01-07 | 2008-01-20 | 257 | 413.6d | 71.62d |  |
| 296 | LC03.11 | Time BPMs to beam |  | 2h | 2008-01-07 | 2008-01-07 |  | 413.6d | 0d |  |
| 297 | LC03.01 | Rough steer through L3/BSY |  | 1d | 2008-01-07 | 2008-01-08 | 296 | 413.6d | 0d |  |
| 298 | 14.3 | Phase all L3 klystrons??? |  | 1d | 2008-01-08 | 2008-01-09 | 297 | 413.6d | 0d |  |
| 299 | LC03.02 | Set RF phase for L3 klystron |  | 4h | 2008-01-09 | 2008-01-09 | 298 | 413.6d | 0d |  |
| 300 | LC03.03 | Set proper energy in BSY |  | 1h | 2008-01-10 | 2008-01-10 | 299 | 413.6d | 0d |  |
| 301 | LC03.04 | Take "oscillation" data |  | 1d | 2008-01-10 | 2008-01-11 | 300 | 413.6d | 0d |  |
| 302 | LC03.05 | Careful steering through L3/BSY |  | 1d | 2008-01-11 | 2008-01-12 | 301 | 413.6d | 0d |  |
| 303 | LC03.06 | Calibrate BPMs w.r.t. toroid |  | 2h | 2008-01-12 | 2008-01-12 | 302 | 413.6d | 0d |  |
| 304 | 14.9 | Beam-base align critical quadrupoles |  | 1d | 2008-01-12 | 2008-01-13 | 303 | 413.6d | 0d |  |
| 305 | LC03.12 | Test TCAV3 bunch-length meas. sofware |  | 3d | 2008-01-13 | 2008-01-16 | 304 | 413.6d | 0d |  |
| 306 | LC03.08 | Measure energy spread in BSY? |  | 1d | 2008-01-16 | 2008-01-17 | 305 | 413.6d | 0d |  |
| 307 | LC03.13 | Measure residual dispersion after BC2 |  | 1d | 2008-01-17 | 2008-01-18 | 306 | 413.6d | 0d |  |
| 308 | LC03.09 | Checkout sec-28 wire scanners |  | 1d | 2008-01-18 | 2008-01-19 | 307 | 413.6d | 0d |  |
| 309 | LC03.10 | Meas. x/y emit. on sec-28 wires |  | 1d | 2008-01-19 | 2008-01-20 | 308 | 413.6d |  |  |
| 310 | 2.35 | LTU Installation complete | milestone | 0d | 2008-03-15 | 2008-03-15 |  | 0d |  | must finish on 2008-03-15 |
| 311 | LC10 | **Pre-Beam Checkout to TDUND (before undulator)** |  | 6d | 2008-03-16 | 2008-03-21 | 310 | 351.98d | 10d |  |
| 312 | LC10.13 | Verify location of all critical components |  | 2d | 2008-03-16 | 2008-03-17 |  | 351.98d | 0d |  |
| 313 | 16.2 | Verify water flow where possible |  | 1d | 2008-03-18 | 2008-03-18 | 312 | 351.98d | 0d |  |
| 314 | LC10.14 | Exercise all motion-controlled devices |  | 1d | 2008-03-19 | 2008-03-19 | 313 | 351.98d | 0d |  |
| 315 | LC10.15 | Verify all OTR camera images |  | 1d | 2008-03-20 | 2008-03-20 | 314 | 351.98d | 0d |  |
| 316 | LC10.16 | Verify polarity of all magnets |  | 1d | 2008-03-21 | 2008-03-21 | 315 | 351.98d |  |  |
| 317 | 2.4 | Ready for Beam to TDUND | milestone | 0d | 2008-04-01 | 2008-04-01 |  | 341.98d | 0d | start no earlier than 2008-04-01 |
| 318 | LC04 | **Beam to TDUND stopper (before undulator)** |  | 15d | 2008-04-01 | 2008-04-15 | 311, 317 | 341.98d | 15d |  |
| 319 | LC04.01 | Start Linac-to-Undulator (LTU) Commissioning | milestone | 0d | 2008-04-01 | 2008-04-01 | 295 | 341.98d | 0d |  |
| 320 | LC04.17 | Insert TDUND tune-up dump |  | 1h | 2008-04-01 | 2008-04-01 | 319 | 341.98d | 0d |  |
| 321 | LC04.04 | Time BPMs to beam |  | 4h | 2008-04-01 | 2008-04-01 | 320 | 341.98d | 0d |  |
| 322 | LC04.10 | Set timing/calibrate toroids |  | 4h | 2008-04-01 | 2008-04-02 | 321 | 341.98d | 0d |  |
| 323 | LC04.06 | Checkout LTU MPS toroid comparator |  | 4h | 2008-04-02 | 2008-04-02 | 322 | 341.98d | 0d |  |
| 324 | LC04.05 | Rough steer through LTU |  | 1d | 2008-04-02 | 2008-04-03 | 323 | 341.98d | 0d |  |
| 325 | LC04.07 | Take "oscillation" data |  | 1d | 2008-04-03 | 2008-04-04 | 324 | 341.98d | 0d |  |
| 326 | LC04.18 | Setup PRTDUND screen |  | 4h | 2008-04-04 | 2008-04-05 | 325 | 341.98d | 0d |  |
| 327 | LC04.11 | Calibrate BPMs w.r.t. toroid |  | 2h | 2008-04-05 | 2008-04-05 | 326 | 341.98d | 0d |  |
| 328 | LC04.08 | Careful steering through LTU |  | 1d | 2008-04-05 | 2008-04-06 | 327 | 341.98d | 0d |  |
| 329 | LC04.20 | Commission abort system |  | 4h | 2008-04-06 | 2008-04-06 | 328 | 341.98d | 0d |  |

Notes:
- 295: GOALS: / ====== / Transport beam through system to 13.6 GeV, establishing initial trajectory, energy, energy spread, and bunch length. Verify MPS systems, checkout and calibrate beam diagnostics, and make first emittance measurements in this system.
- 296: Step BPM timing in 8-ns steps to find beam on each BPM - save timing.
- 297: Rough steering of beam through L3/BSY: / ·Measure BPMs up to BPM92103 / ·Empirically adjust correctors up to XCA0 and YCA0
- 299: Set RF phase for L3 klystron: / ·Measure BPM 57 x in BSY (50B1 on) / ·Scan L3 RF phase (all 29-30 klystrons) / ·Set to crest phase
- 300: Set proper energy in BSY: / ·Set BPM FB31 57 » 0 / ·Set L3 voltage
- 301: Confirm linear optics, BPM scaling, and correctors with respect to on-line model: / ·Measure difference orbit of all BPMs up to BPM92103 / ·Scan all correctors from XC24901/YC24901 to XCVM2/YCVM1
- 302: Careful steering of beam through L3/BSY (software checkout?): / ·Measure BPMs up to BPM 57 in BSY / ·Automated adjustment of correctors up to XC30801, YC30900
- 303: Calibrate BPM intensities w.r.t. toroid IMBC2O
- 304: Apply beam-based alignment to several critical quadrupole magnets: / ·Measure BPM variations vs. quadrupole gradients / ·Use linear fit to calculate misalignment (x and y) / ·Steer beam to center (or schedule tunnel alignment if > ~1 mm) / ·Document changes / ·Do at least for quadrupoles: Q24901A/B, QM22 (Q24901A/B on same power supply)
- 305: Test new software designed to make fast bunch length measurements using the transverse deflecting RF cavity. / The software should set the TCAV phase to each zero-crossing point, plus TCAV-off, and measure the vertical beam size on OTR2, then fit a parabola to these 3 points, and crom this calculate the bunch length. The software must also have a calibrate function which will also be used to calibrate the vertical screen pixels into S-band degrees by varying the RF phase around the zero crossing and linearly fitting the beam centroid on the screen.
- 306: Measure energy spread on BSY wire (CA11 62? or PR55 screen):
- 307: Measure residual x and y dispersion just after BC2: / ·Measure x & y BPMs from BPMS21 to BPM25901 / ·Vary BC2 energy setpoint +-1% / ·Correlate BPMS21/etaX with BPM x & y readings / ·Correct x dispersion with CQ21 & CQ22
- 308: Checkout wire scanners: WS044, WS144, WS444, and WS544: / ·Measure beam x and y centers on each wire / ·Scan the precision-calibrated correctors: none
- 309: Measure x/y emittance on sector-28 wires: WS044, WS144, WS444, and WS544:
- 312: In tunnel: / -measure z-location of all quadrupoles, dipoles, correctors, BPMs, collimators, wire-scanners, OTR/YAG screens / -Visually inspect terminal connections to magnets / -Verify cable labels match magnets / -Remove mis-laid tools, etc
- 314: Exercise full range motion-control for all: / -wire-scanners (WS31,32,33,34) / -OTR insertable screens (OTR30,OTR33) / -collimators (CEDL1,CEDL3,CX31,CY32,CX35,CY36,CX37,CY38) / -Tune-up dumps (TDUND) / -make sure all are removed (except TDUND) before beam ON
- 315: Verify image of OTR/Cro insertable screens: / -OTR30 (in DL2) / -OTR33 (in LTU) / -PRUND (screen on TDUND)
- 316: With power on access: / -Possibly probe-eye all magnet terminals at nominal settings / -Test polarity of all quadrupoles, dipoles, and correctors / -Use flipper coil or Hall probe
- 318: GOALS: / ====== / Transport beam through system, establishing initial trajectory, energy, energy spread, and bunch length. Verify MPS systems, checkout and calibrate beam diagnostics, and make first emittance measurements in this system.
- 320: Rate limited to 10 Hz with TDUND in.
- 321: Step BPM timing in 8-ns steps to find beam on each BPM - save timing.
- 322: Set timing and calibrate toroids IM31, and IM36
- 323: Checkout MPS toroid comparator across LTU: / ·Compare and trip MPS as IM36/IM31 < ~0.9 (?) / ·Any Dark-current issues? / ·Induce beam loss in LTU with collimator CEDL1 or CEDL3
- 324: Rough steering of beam through LTU: / ·With tune-up stopper IN (TDUND), / ·Measure BPMs up to BPMUM4 / Empirically adjust correctors up to XCUM4, YCUM3
- 325: Confirm linear optics, BPM scaling, and correctors with respect to on-line model: / ·Measure difference orbit of all BPMs up to BPMUM4 / ·Scan all correctors from XCVM2/YCVM1 to XCUM4/YCUM3
- 326: Setup beam on Tune-up-Dump screen, PRTDUND, before undulator: / ·Setup video systems / ·Move beam to estimate calibration, etc?
- 327: Calibrate BPM intensities w.r.t. toroid IM31
- 328: Careful steering of beam through LTU (software checkout?): / ·Measure BPMs up to BPMUM4 / ·Automated adjustment of correctors up to XCUM4 and YCUM3
- 329: Setup and checkout abort kicker and dump in LTU: / ·Measure BPMDL2 y/ ·Turn on BYKIK vertical pulsed magnet to 0.6 kG-m / ·Scan timing of BYKIK vertical pulsed magnet / ·The BPMDL2 y-reading should be about -9 mm at maximum / ·Test 1, 10, and 30 Hz rate-limits and 'one-shot' using abort logic / ·Test MPS connections available (e.g., TDUND rate-limit to 10 Hz)

| ID | WBS | Task | Type | Duration | Start | Finish | Predecessors | Total slack | Free slack | Constraint |
| --- | --- | --- | --- | --- | --- | --- | --- | --- | --- | --- |
| 330 | LC04.19 | **Setup energy feedback on L3/DL2** |  | 2.62d | 2008-04-06 | 2008-04-09 | 329 | 341.98d | 0d |  |
| 331 | LC04.19.16 | Calibrate BPM13 X-readback |  | 2h | 2008-04-06 | 2008-04-07 |  | 341.98d | 0d |  |
| 332 | LC04.19.17 | Verify optics from BPMDL1-3 |  | 4h | 2008-04-07 | 2008-04-07 | 331 | 341.98d | 0d |  |
| 333 | LC04.19.18 | Save feedback reference orbit |  | 2h | 2008-04-07 | 2008-04-07 | 332 | 341.98d | 0d |  |
| 334 | LC04.19.19 | Switch on feedback |  | 1h | 2008-04-07 | 2008-04-07 | 333 | 341.98d | 0d |  |
| 335 | LC04.19.20 | Test feedback step response |  | 4h | 2008-04-08 | 2008-04-08 | 334 | 341.98d | 0d |  |
| 336 | LC04.19.21 | Debug feedback code |  | 1d | 2008-04-08 | 2008-04-09 | 335 | 341.98d |  |  |
| 337 | 18.13 | Beam-base align critical quadrupoles |  | 1d | 2008-04-09 | 2008-04-10 | 330 | 341.98d | 0d |  |
| 338 | LC04.09 | **Set beam center/align the collimators** |  | 1d | 2008-04-10 | 2008-04-11 | 337 | 341.98d | 0d |  |
| 339 | LC04.09.01 | Set beam center/align the collimators |  | 1d | 2008-04-10 | 2008-04-11 |  | 341.98d | 0d |  |
| 340 | LC04.09.02 | **Beam profile** |  | 0d | 2008-04-11 | 2008-04-11 | 339 | 341.98d |  |  |
| 341 | LC04.09.02.01 | CX31 | milestone | 0d | 2008-04-11 | 2008-04-11 |  | 341.98d |  |  |
| 342 | LC04.09.02.02 | CY32 | milestone | 0d | 2008-04-11 | 2008-04-11 |  | 341.98d |  |  |
| 343 | LC04.09.02.03 | **CX37** |  | 0d | 2008-04-11 | 2008-04-11 |  | 341.98d |  |  |
| 344 | LC04.09.02.03.1 | Contour | milestone | 0d | 2008-04-11 | 2008-04-11 |  | 341.98d |  |  |
| 345 | LC04.09.02.03.2 | x-histogram | milestone | 0d | 2008-04-11 | 2008-04-11 |  | 341.98d |  |  |
| 346 | LC04.09.02.04 | **CY38** |  | 0d | 2008-04-11 | 2008-04-11 |  | 341.98d |  |  |
| 347 | LC04.09.02.04.1 | Contour | milestone | 0d | 2008-04-11 | 2008-04-11 |  | 341.98d |  |  |
| 348 | LC04.09.02.04.2 | x-histogram | milestone | 0d | 2008-04-11 | 2008-04-11 |  | 341.98d |  |  |
| 349 | LC04.12 | Calibrate x,y-scale of LTU OTR33 |  | 4h | 2008-04-11 | 2008-04-11 | 338 | 341.98d | 0d |  |
| 350 | LC04.13 | Calibrate x-scale of LTU OTR30 |  | 4h | 2008-04-12 | 2008-04-12 | 349 | 341.98d | 0d |  |
| 351 | LC04.14 | Measure energy spread in LTU |  | 4h | 2008-04-12 | 2008-04-12 | 350 | 341.98d | 0d |  |
| 352 | LC04.21 | Measure residual dispersion after DL2 |  | 1d | 2008-04-13 | 2008-04-13 | 351 | 341.98d | 0d |  |
| 353 | LC04.15 | Checkout wire scanners |  | 1d | 2008-04-14 | 2008-04-14 | 352 | 341.98d | 0d |  |
| 354 | LC04.16 | Meas. x/y emit. on wires |  | 1d | 2008-04-15 | 2008-04-15 | 353 | 341.98d |  |  |
| 355 | 2.38 | Dump Installation Complete | milestone | 0d | 2008-03-15 | 2008-03-15 |  | 0d |  | must start on 2008-03-15 |

Notes:
- 330: Follow steps below to commission DL2 energy feedback loop / The feedback loop adjusts L3 RF voltage and uses BPMDL1 & BPMDL3 to measure the beam energy (125 mm dispersion on each BPM)
- 331: Calibrate x-scale of BPMDL1 & 3 between DL2 bend pairs: / ·Measure BPMDL1 & 3 x-position (125 mm dispersion each) / ·Scan 3 RF voltage (29-30) a known amount
- 332: Verify optics from BPMDL1 to BPMDL3 (R = +I): / ·Measure BPMDL1 & 3, x/ ·Scan XCVM3 / ·Ensure diff: BPMDL1(x) - BPMDL3(x) is uncorrelated to XCVM3 / ·Fix any problems before proceeding
- 333: Save reference orbit from BPMDL1 & 3 for feedback goal: / ·Measure BPMDL1, 3 x/ ·Save reference file of readings into feedback ref. file
- 335: Test step-function response of feedback loop: / ·Change beam energy with 29-30 klytrons voltage or phase / ·Record response vs. time of feedback loop signal (BPMDL1-DL3) / ·Verify XCVM3 & YCVM4 changes do not affect energy, etc
- 336: Debug beam-based feedback code, at least for this DL2 energy loop.
- 337: Apply beam-based alignment to several critical quadrupole magnets: / ·Measure BPM variations vs. quadrupole gradients / ·Use linear fit to calculate misalignment (x and y) / ·Steer beam to center (or schedule tunnel alignment if > ~1 mm) / ·Document changes / ·Do at least for quadrupoles: Q5, Q6, QVM1, QVM2, QVM3, QVM4, QT11/13, QT12, QT21/23, QT22, QT31/33, QT32, QT41/43, QT42 / ·(QTi1/i3, for i = 1,2,3,4, are all 8 on same supply; QTi2, for i = 1,2,3,4, are all 4 on same supply)
- 338: Find the center of the beam and align the collimators: / ·Move each jaw of CX31, CX35, and CX37 to find the beam x-center / ·Move each jaw of CY32, CY36, and CY38 to find the beam y-center
- 343: The profile is asymetric, though the beam size is too small compared with the distance between two jaws.
- 346: The profile is asymetric, though the beam size is too small compared with the distance between two jaws.
- 349: Calibrate x,y-scale of OTR33 screen in LTU: / ·Measure OTR33 mean x-position and scan corrector XCEM4 / ·Measure OTR33 mean y-position and scan corrector YCEM3
- 350: Calibrate x-scale of OTR30 screen in LTU: / ·Measure OTR30 mean x-position and scan prec-calib-corrector XCVM2
- 351: Measure energy spread in LTU: / ·Measure horizontal beam size on OTR30 screen in LTU
- 352: Measure residual x and y dispersion just after DL2: / ·Measure x & y BPMs from BPMDL1 to BPME36 / ·Vary DL2 energy setpoint +-1% / ·Correlate (BPMDL1-BPMDL3)/etaX/2 with BPM x & y readings / ·Correct x dispersion with QDL31 or QDL33 ?
- 353: Checkout wire scanners: WS31, WS32, WS33, and WS34:/ ·Measure beam x and y centers on each wire / ·Scan the precision-calibrated correctors: XCVM2 and YCVM1
- 354: Measure x/y emittance on LTU wires: WS31, WS32, WS33, and WS34:

| ID | WBS | Task | Type | Duration | Start | Finish | Predecessors | Total slack | Free slack | Constraint |
| --- | --- | --- | --- | --- | --- | --- | --- | --- | --- | --- |
| 356 | LC12 | **Pre-Beam Checkout to Main Dump** |  | 3.5d | 2008-03-15 | 2008-03-18 | 355 | 360.48d | 33.5d |  |
| 357 | LC12.17 | Verify location of all critical components |  | 1d | 2008-03-15 | 2008-03-15 |  | 360.48d | 0d |  |
| 358 | 20.2 | Verify water flow where possible |  | 1d | 2008-03-16 | 2008-03-16 | 357 | 360.48d | 0d |  |
| 359 | LC12.18 | Exercise all motion-controlled devices |  | 2h | 2008-03-17 | 2008-03-17 | 358 | 360.48d | 0d |  |
| 360 | LC12.19 | Verify all OTR camera images |  | 2h | 2008-03-17 | 2008-03-17 | 359 | 360.48d | 0d |  |
| 361 | LC12.20 | Verify polarity of all magnets |  | 1d | 2008-03-17 | 2008-03-18 | 360 | 360.48d |  |  |
| 362 | 2.5 | Ready for Beam to Main Electron Dump | milestone | 0d | 2008-05-01 | 2008-05-01 |  | 0d |  | start no earlier than 2008-05-01 |
| 363 | LC11 | **Beam to main dump** |  | 8.02d | 2008-05-01 | 2008-05-09 | 356FS+10d, 362 | 326.98d |  |  |
| 364 | 22.1 | Roll out all undulators |  | 1h | 2008-05-01 | 2008-05-01 | 318 | 326.98d | 0d |  |
| 365 | 22.2 | Set machine rate to 'one-shot' mode |  | 1h | 2008-05-01 | 2008-05-01 | 364 | 326.98d | 0d |  |
| 366 | 22.3 | Open TDUND |  | 1h | 2008-05-01 | 2008-05-01 | 365 | 326.98d | 0d |  |
| 367 | 22.4 | Sample one-shot orbit on und-BPMs |  | 1h | 2008-05-01 | 2008-05-01 | 366 | 326.98d | 0d |  |
| 368 | 22.5 | Roughly correct undulator trajectory |  | 10min | 2008-05-01 | 2008-05-01 | 367 | 326.98d | 0d |  |
| 369 | 22.6 | Establsh <0.5-mm trajectory |  | 1h | 2008-05-01 | 2008-05-01 | 368 | 326.98d | 0d |  |
| 370 | 22.7 | Set 1-Hz rate to dump |  | 1h | 2008-05-01 | 2008-05-01 | 369 | 326.98d | 0d |  |
| 371 | LC11.02 | Time BPMs to beam |  | 4h | 2008-05-01 | 2008-05-02 | 370 | 326.98d | 0d |  |
| 372 | LC11.03 | Set timing/calibrate toroids |  | 4h | 2008-05-02 | 2008-05-02 | 371 | 326.98d | 0d |  |
| 373 | LC11.04 | Checkout DUMP MPS toroid comparator |  | 4h | 2008-05-02 | 2008-05-03 | 372 | 326.98d | 0d |  |
| 374 | LC11.05 | Rough steer through dump |  | 4h | 2008-05-03 | 2008-05-03 | 373 | 326.98d | 0d |  |
| 375 | LC11.17 | Radiation Physics measurements in dump |  | 1d | 2008-05-03 | 2008-05-04 | 374 | 326.98d | 0d |  |
| 376 | LC11.06 | Take "oscillation" data |  | 4h | 2008-05-04 | 2008-05-05 | 375 | 326.98d | 0d |  |
| 377 | LC11.08 | Calibrate BPMs w.r.t. toroid |  | 2h | 2008-05-05 | 2008-05-05 | 376 | 326.98d | 0d |  |
| 378 | LC11.16 | Checkout safety dump |  | 1d | 2008-05-05 | 2008-05-06 | 377 | 326.98d | 0d |  |
| 379 | LC11.09 | Careful steering through dump |  | 4h | 2008-05-06 | 2008-05-07 | 378 | 326.98d | 0d |  |
| 380 | LC11.12 | Setup OTRDMP screen |  | 4h | 2008-05-07 | 2008-05-07 | 379 | 326.98d | 0d |  |
| 381 | LC11.10 | Calibrate y-scale of OTRDMP |  | 4h | 2008-05-07 | 2008-05-08 | 380 | 326.98d | 0d |  |
| 382 | LC11.14 | Measure dispersion in dump line |  | 4h | 2008-05-08 | 2008-05-08 | 381 | 326.98d | 0d |  |
| 383 | LC11.11 | Measure energy spread in dump line |  | 4h | 2008-05-08 | 2008-05-09 | 382 | 326.98d |  |  |

Notes:
- 357: In tunnel: / -measure z-location of all quadrupoles, dipoles, correctors, BPMs, collimators, wire-scanners, OTR/YAG screens / -Visually inspect terminal connections to magnets / -Verify cable labels match magnets / -Remove mis-laid tools, etc
- 359: Exercise full range motion-control for all: / -OTR insertable screens (OTRDMP) / -make sure all are removed before beam ON
- 360: Verify image of OTR/Cro insertable screens: / -OTRDMP (in dump line)
- 361: With power on access: / -Possibly probe-eye all magnet terminals at nominal settings / -Test polarity of all quadrupoles, dipoles, and correctors / -Use flipper coil or Hall probe
- 363: GOALS: / ====== / Transport beam through undulator quicky, without loss, establishing rough trajectory, in order to establish beam on dump at 1 Hz prior to any undulator commissioning work.
- 369: Repeat one-shots and rough corrections until trajectory < 0.5 mm everywhere in x and y
- 371: Step BPM timing in 8-ns steps to find beam on each BPM - save timing.
- 372: Set timing and calibrate toroids IMUNDO, and IMDUMP
- 373: Checkout MPS toroid comparator across dump: / ·Compare and trip MPS as IMDUMP/IMUNDO < ~0.9 (?) / ·Induce beam loss in dumpline with steering
- 374: Rough steering of beam through dump: / ·Measure BPMs up to BPMDD / ·Empirically adjust correctors up to XCDD, YCDD
- 375: Must get Radiation Physics to measure background radiation in FEE and dump area and give approval, before continuing commissioning work.
- 376: Confirm linear optics, BPM scaling, and correctors with respect to on-line model: / ·Measure difference orbit of all BPMs up to BPMDD / ·Scan all correctors from XCUE1/YCUE1 to XCDD /YCDD
- 377: Calibrate BPM intensities w.r.t. toroid IMDUMP
- 379: Careful steering of beam through dump (software checkout?): / ·Measure BPMs up to BPMDD / ·Automated adjustment of correctors up to XCDD and YCDD
- 380: Setup beam on dump screen, OTRDMP, after undulator: / ·Setup video systems / ·Move beam to estimate calibration, etc?
- 381: Calibrate y-scale of OTRDMP screen: / ·Measure OTR30 mean y-position and scan beam energy
- 382: Measure dispersion in dump line on BPMDD: / ·Measure BPMDD mean y-position and scan beam energy / ·Correlate the two (etaY = 653 mm)
- 383: Measure energy spread in dump line: / ·Measure vertical beam size on OTRDMP screen
